# 3GPP_Work Plan

Schedule from MS Project, 2000-01-03 to 2005-12-16, A marks actual dates.

## Calendars

- Standard: Mon-Fri 08:00-12:00, 13:00-17:00; Sat-Sun off.

## Resources

| Resource | Cost per use |
| --- | --- |
| NP | 12475200 |
| N1 |  |
| N2 |  |
| N3 |  |
| N4 |  |
| N5 |  |
| TP |  |
| T1 |  |
| T2 |  |
| T3 |  |
| RP |  |
| R1 |  |
| R2 |  |
| R3 |  |
| R4 |  |
| SP |  |
| S1 |  |
| S2 |  |
| S3 |  |
| S4 |  |
| S5 |  |
| PCG |  |
| GP |  |
| No |  |
| CN4 |  |
| ? |  |
| WG G2 |  |
| G2 |  |
| G1 |  |
| G4 |  |
| G3 |  |
| All |  |
| Generic |  |
| MLST |  |
| G5 |  |
| S3, G2 |  |
| WG T2 |  |
| GP,G1 |  |
| G4,G5 |  |
| OMA |  |
| GP-G2 |  |
| Yes |  |

## Schedule

| ID | WBS | Task | Duration | Start | Finish | Complete | Remaining | Baseline start | Baseline finish | Baseline duration | Total slack | Constraint | Resources | Work | Actual work | Text6 | Text9 | Text1 | Text4 | Text5 | Text7 | Text8 | Text11 | Text10 | Text2 | Text3 | Text12 |
| --- | --- | --- | --- | --- | --- | --- | --- | --- | --- | --- | --- | --- | --- | --- | --- | --- | --- | --- | --- | --- | --- | --- | --- | --- | --- | --- | --- |
| 1 | 1 | VERSION 2004 January 16th | 1d | 2000-01-03 | 2000-01-03 |  |  | 2000-01-03 | 2000-01-03 | 1d | 1554d |  |  |  |  | Rel | 2044 |  |  |  |  |  |  |  |  |  |  |
| 2 | 2 | "CTRL + a" to display all the 3GPP fields | 1d | 2000-01-03 | 2000-01-03 |  |  | 2000-01-03 | 2000-01-03 | 1d | 1294d |  |  |  |  |  | 1462 |  |  |  |  |  |  |  |  |  |  |
| 3 | 3 | Content of Rel-6 and after. Not frozen. | 1d | 2000-01-03 | 2000-01-03 |  |  | 2000-01-03 | 2000-01-03 | 1d | 1294d |  |  |  |  | Rel | 2058 |  |  |  |  |  |  |  |  |  |  |
| 5 | 4 | Evolutions of the transport in the UTRAN | 218d | 2003-03-03 | 2003-12-31 |  |  |  |  |  | 512d | start no earlier than 2003-03-03 | RP | 1744h |  | NA | Feat | ETRAN | Francois Courau, Alcatel | francois.courau@alcatel.fr | TSG | MCC_RAN | Generic |  |  |  |  |
| 6 | 8 | **Improvements of Radio Interface** | 1067d | 2000-08-14 A | 2004-09-14 | 67% | 353d | 2000-08-14 | 2004-03-19 | 940d? | 328d |  | RP | 75872h | 47613.2h | Rel-6 |  | RInImp |  |  | TSG |  |  |  |  |  |  |
| 7 | 5.1 | Improvement of inter-frequency and inter-system measurement | 835d | 2001-01-01 A | 2004-03-12 | 50% | 417.5d |  |  |  | 460d | start no earlier than 2001-01-01 | R1 | 6680h | 3340h | Rel-6 | BB | RInImp-IfIsM | Antti Toskala, Nokia | antti.toskala@nokia.com | TSG | MCC_RAN | Active | 1216 |  |  |  |
| 8 | 5.2 | Improving Receiver Performance Requirements for the FDD UE | 401d | 2002-03-08 A | 2003-09-19 A | 100% |  |  |  |  |  | start no earlier than 2002-03-08 | R4 | 3208h | 3208h | Rel-6 | BB | RInImp-UERecPerf | Shimon Moshavi, Intel | shimon.moshavi@INTEL.COM | TSG |  | Active | 1216 |  |  |  |
| 9 | 8.2 | **Base station classification** | 603d | 2000-08-14 A | 2002-12-04 A | 100% |  | 2000-08-14 | 2002-12-04 | 603d |  |  | R4 | 9648h | 9648h | Rel-6 |  | RInImp-BSClass |  |  | TSG |  |  |  |  |  |  |
| 10 | 8.2.1 | FDD Base station classification | 603d | 2000-08-14 A | 2002-12-04 A | 100% |  | 2000-08-14 | 2002-12-04 | 603d |  | finish no earlier than 2002-12-04 | R4 | 4824h | 4824h | Rel-6 | 1476 | RInImp-BSClass-FDD | A. Toskala, Nokia |  | TSG |  |  |  | BaAs |  |  |
| 11 | 5.4 | UMTS-850 | 266d | 2002-12-06 A | 2003-12-12 A | 100% |  |  |  |  |  | finish no earlier than 2003-12-15 | R4 | 2128h | 2128h | Rel-6 | BB | RInImp-UMTS850 | Don Zelmer, Cingular | don.zelmer@cingular.com | TSG | MCC_RAN | Active | 1216 |  |  |  |
| 12 | 5.5 | DS-CDMA introduction in the 800 MHz band | 196d | 2003-03-14 A | 2003-12-12 A | 100% |  |  |  |  |  | finish no earlier than 2003-12-15 | R4 | 1568h | 1568h | Rel-6 | BB | RInImp-UMTS800 | Takehiro Nakamura, NTT DoCoMo | takehiro@wsp.yrp.nttdocomo.co.jp | TSG | MCC_RAN | Active | 1216 |  |  |  |
| 13 | 5.6 | UMTS 1.7/2.1 GHz | 261d | 2003-03-14 A | 2004-03-12 | 90% | 26.1d |  |  |  | 460d | finish no earlier than 2004-03-12 | R4 | 2088h | 1879.2h | Rel-6 | BB | RInImp-UMTS1721 | Jussi Numminen, Nokia | jussi.numminen@NOKIA.COM | TSG | MCC_RAN | Active | 1216 |  |  |  |
| 14 | 5.7 | **Improved Receiver Performance Requirements for HSDPA** | 197d | 2003-12-15 | 2004-09-14 |  |  |  |  |  | 328d |  | R4 | 3152h |  | Rel-6 |  | RInImp-HSPerf | Jussi Numminen, Nokia | jussi.numminen@NOKIA.COM | TSG | MCC_RAN |  |  |  |  |  |
| 15 | 5.7.1 | Performance Requirements of Receive Diversity for HSDPA | 197d | 2003-12-15 | 2004-09-14 |  |  |  |  |  | 328d | start no earlier than 2003-12-15 | R4 | 1576h |  | Rel-6 |  | RInImp-HSPerf-RxDiv | Takehiro Nakamura (NTT DoCoMo) | takehiro@wsp.yrp.nttdocomo.co.jp | TSG | MCC_RAN |  |  |  | TS25.101 |  |
| 16 | 5.8 | **Feasibility Studies** | 1067d | 2000-08-14 A | 2004-09-14 | 60% | 422.69d |  |  |  | 328d |  | RP | 38864h | 20130h | Rel-6 |  |  |  |  |  |  |  |  |  |  |  |
| 17 | 5.8.1 | FS on Radio link performance enhancements | 940d | 2000-08-14 A | 2004-03-19 | 50% | 470d |  |  |  | 455d | start no earlier than 2000-08-14 | R1 | 7520h | 3760h | Rel-6 | SI | RInImp-Rlperf | Antti Toskala, Nokia Networks | antti.toskala@nokia.com | TSG | MCC_RAN | Active | 1216 |  |  |  |
| 18 | 5.8.2 | FS on UTRA WideBand Distribution Systems | 790d | 2001-03-12 A | 2004-03-19 | 60% | 316d |  |  |  | 455d | start no earlier than 2001-03-12 | R4 | 6320h | 3792h | Rel-6 | SI | RInImp-WDS | Andrea Casini, Tekmar Sistemi | carlo.matarasso@andrew.com | TSG | MCC_RAN | Active | 1216 |  |  |  |
| 19 | 5.8.3 | FS on Improvement of inter-frequency and inter-system measurements for 1.28 Mcps TDD | 461d | 2001-12-14 A | 2003-09-19 A | 100% |  |  |  |  |  | start no earlier than 2001-12-14 | R1 | 3688h | 3688h | Rel-6 | SI | RInImp-IfIsMLCR | Li Xiao Qiang, SAMSUNG | xqli@samsung.co.kr | TSG |  | Active | 1216 |  |  | 10 |
| 20 | 5.8.4 | FS for the analysis of OFDM for UTRAN enhancement | 526d | 2002-06-10 A | 2004-06-14 | 55% | 236.7d |  |  |  | 394d | start no earlier than 2002-06-10 | R1 | 4208h | 2314.4h | Rel-6 | SI | RInImp-FSOFDM | Sarah Boumendil, Nortel | boumendi@nortelnetworks.com | TSG | MCC_RAN | Active | 1216 |  |  | 11 |
| 21 | 5.8.5 | FS on Uplink Enhancements for Dedicated Transport Channels | 396d | 2002-09-06 A | 2004-03-12 | 65% | 138.6d |  |  |  | 460d | finish no earlier than 2004-03-12 | R1 | 3168h | 2059.2h | Rel-6 | SI | RInImp-FSUpDTrCh | Karri Ranta-aho, Nokia | Karri.Ranta-aho@nokia.com | TSG | MCC_RAN | Active | 1216 |  |  | 12 |
| 22 | 5.8.6 | FS on Analysis on Higher Chip Rates for UTRA TDD evolutions | 462d | 2002-09-06 A | 2004-06-14 | 75% | 115.5d |  |  |  | 394d | finish no earlier than 2004-06-14 | R1 | 3696h | 2772h | Rel-6 | SI | RInImp-FSVHCRTDD | Tim Wilkinson, IPWireless | mbeale@ipwireless.com | TSG | MCC_RAN | Active | 1216 |  |  | 13 |
| 23 | 5.8.7 | FS on Low Output Powers for general purpose FDD BSs | 128d | 2003-06-13 A | 2004-03-12 | 55% | 57.6d |  |  |  | 460d | finish no earlier than 2004-03-12 | R3 | 1024h | 563.2h | Rel-6 | SI | RInImp-FSLoPw | Ana Burgos, Telefonica | burgos_a@tsm.es | TSG | MCC_RAN | Active | 1216 |  |  | 14 |
| 24 | 5.8.8 | FS on Uplink enhancements for UTRA TDD | 333d | 2003-06-06 A | 2004-09-14 | 5% | 316.35d |  |  |  | 328d | finish no earlier than 2004-09-14 | R1 | 2664h | 133.2h | Rel-6 | SI | RInImp-FSUpEnhTDD | Marian Rudolf, Interdigital | Marian.Rudolf@InterDigital.com | TSG | MCC_RAN | Active | 1216 |  |  | 15 |
| 25 | 8.8 | FS on UE antenna efficiency test methods performance requirements (2) | 131d | 2002-03-08 A | 2002-09-06 A | 100% |  | 2002-03-08 | 2002-09-06 | 131d |  | finish no earlier than 2002-09-06 | R4 | 1048h | 1048h | Rel-6 |  | RInImp-UEAnTM2 | Alf Ahlström, Allgon |  | TSG |  |  |  |  |  |  |

Notes:
- 5: Generic feature
- 6: This is a generic feature without particular end date
- 14: Approved at TSG RAN#22 as RP-030732
- 15: Approved at TSG RAN#22 as RP-030731
- 25: The RInImp-UEAnTM FS was re-opened at TSG RAN#15 upon request from WG4

| ID | WBS | Task | Duration | Start | Finish | Complete | Remaining | Baseline start | Baseline finish | Baseline duration | Total slack | Constraint | Resources | Work | Actual work | Text1 | Text4 | Text5 | Text6 | Text7 | Text8 | Text9 | Text2 | Text3 | Text10 | Text11 | Text12 |
| --- | --- | --- | --- | --- | --- | --- | --- | --- | --- | --- | --- | --- | --- | --- | --- | --- | --- | --- | --- | --- | --- | --- | --- | --- | --- | --- | --- |
| 26 | 8.5 | **Multiple Input Multiple Output antennas (MIMO)** | 461d? | 2003-03-14 A | 2004-12-17 | 17% | 381.18d? | 2003-03-14 | 2004-12-17 | 461d? | 260d |  | R1 | 14208h | 3920.8h | MIMO | Howard Huang, Lucent | hchuang@lucent.com | Rel-6 | TSG | MCC_RAN | 2468 |  |  |  |  |  |
| 27 | 6.1 | Multiple Input Multiple Output antennas - Physical layer | 393d? | 2003-03-14 A | 2004-09-14 | 40% | 235.8d? | 2003-03-14 | 2004-03-19 | 266d? | 328d | finish no earlier than 2004-09-14 | R1 | 3144h | 1257.6h | MIMO-Phys | Howard Huang, Lucent | hchuang@lucent.com | Rel-6 | TSG | MCC_RAN |  |  |  |  |  |  |
| 28 | 6.2 | Multiple Input Multiple Output antennas - Layer 2,3 aspects | 263d? | 2003-09-12 | 2004-09-14 |  |  | 2003-09-12 | 2004-03-19 | 136d? | 328d | start no earlier than 2003-09-12 | R2 | 2104h |  | MIMO-L23 | Howard Huang, Lucent | hchuang@lucent.com | Rel-6 | TSG | MCC_RAN |  |  |  |  |  |  |
| 29 | 6.3 | Multiple Input Multiple Output antennas - Iub/Iur Protocol Aspects | 393d? | 2003-03-14 | 2004-09-14 |  |  | 2003-03-14 | 2003-09-19 | 136d? | 328d | finish no earlier than 2004-09-14 | R3 | 3144h |  | MIMO-IurIub | Howard Huang, Lucent | hchuang@lucent.com | Rel-6 | TSG | MCC_RAN |  |  |  |  |  |  |
| 30 | 6.4 | Multiple Input Multiple Output antennas - RF Radio Transmission/Reception, System Performance Requirements and Conformance Testing | 266d? | 2003-12-12 A | 2004-12-17 | 27% | 195.5d? | 2003-12-12 | 2004-12-17 | 266d? | 260d | finish no earlier than 2004-12-17 | R4 | 2128h | 564h | MIMO-RF | Man Hung Ng, Lucent | ngm@lucent.com | Rel-6 | TSG | MCC_RAN |  |  |  |  |  |  |
| 31 | 9 | **RAN improvements** | 975d? | 2002-03-25 A | 2005-12-16 | 50% | 489.99d? | 2001-12-14 | 2004-03-19 | 591d? | 0d |  | RP | 32888h | 13196.8h | RANimp |  |  | Rel-6 | TSG | MCC_RAN |  |  |  |  |  |  |
| 32 | 9.2 | **RAB support enhancement** | 266d? | 2003-03-14 A | 2004-03-19 | 20% | 212.8d? | 2003-03-14 | 2004-03-19 | 266d? | 455d |  | R2 | 4256h | 638.4h | RANimp-RABSE | Juha Mikola, Nokia | juha.mikola@nokia.com | Rel-6 | TSG | MCC_RAN | 624 | BaAS |  |  |  |  |
| 33 | 7.1.1 | Iu enhancements for IMS support in RAN | 266d? | 2003-03-14 A | 2004-03-19 | 20% | 212.8d? | 2003-03-14 | 2004-03-19 | 266d? | 455d | finish no earlier than 2004-03-19 | R3 | 2128h | 425.6h | RANimp-RABSE-IuEnhIMS | Phillipe Godin, Nortel | Philippe.Godin@nortelnetworks.com | Rel-6 | TSG | MCC_RAN |  |  |  |  |  |  |
| 34 | 9.3 | Improvement of RRM across RNS and RNS/BSS | 445d | 2002-03-25 A | 2003-12-05 | 35% | 289.25d | 2002-03-25 | 2003-12-05 | 445d | 530d | finish no earlier than 2003-12-05 | R3 | 3560h | 1246h | RANimp-RRM1 | Antti Toskala, Nokia | antti.toskala@nokia.com | Rel-6 | TSG |  |  |  |  |  |  |  |
| 35 | 9.1 | Beamforming Enhancements | 586d | 2003-09-19 A | 2005-12-16 A | 100% |  | 2001-12-14 | 2003-09-19 | 461d |  | finish no earlier than 2004-03-12 | R1 | 4688h | 4688h | RANimp-BFE | Jussi Kähtävä, Nokia | jussi.kahtava@nokia.com | Rel-6 | TSG | MCC_RAN |  |  |  |  |  |  |
| 36 | 7.4 | **Rel6 RRM optimization for Iur and Iub** | 126d | 2003-09-19 A | 2004-03-12 | 60% | 50.4d | 2002-12-06 | 2003-09-19 | 206d? | 460d |  | R3 | 2016h | 604.8h | RANimp-RRMopt | Gert-Jan van Lieshout, Ericsson | Gert-Jan.van.Lieshout@eln.ericsson.se | Rel-6 | TSG | MCC_RAN |  | BaAS |  |  |  |  |
| 37 | 7.4.1 | Improved access to User Equipment (UE) measurement data for Controlling Radio Network Controller (CRNC) to support Time Division Duplex (TDD) Radio Resource Management (RRM) | 126d | 2003-09-19 A | 2004-03-12 | 60% | 50.4d |  |  |  | 460d | start no earlier than 2003-09-19 | R3 | 1008h | 604.8h | RANimp-RRMopt-UEMsD | Jim Miller, Interdigital | jim.miller@interdigital.com | Rel-6 | TSG | MCC_RAN | WT |  | TS25.423 | 23012 | Active | 22 |
| 38 | 7.5 | Remote Control of Electrical Tilting Antennas | 261d? | 2003-03-14 A | 2004-03-12 | 30% | 182.7d? | 2003-03-14 | 2003-12-05 | 191d? | 460d | finish no earlier than 2004-03-12 | R3 | 2088h | 626.4h | RANimp-TiltAnt | Andreas Hauser, Vodafone | Andreas.Hauser@vodafone.com | Rel-6 | TSG | MCC_RAN |  |  |  |  |  |  |
| 39 | 7.6 | Network Assisted Cell Change (NACC) from UTRAN to GERAN - network-side aspects | 395d? | 2002-09-09 A | 2004-03-12 | 17% | 327.85d? | 2003-06-13 | 2003-12-19 | 136d? | 460d | start no earlier than 2002-09-09 | R3 | 3160h | 537.2h | RANimp-NACC | Brendan McWilliams, Vodafone | Brendan.McWilliams@gb.vodafone.co.uk | Rel-6 | TSG | MCC_RAN |  |  |  |  |  |  |
| 40 | 7.7 | FS of the improved access to UE measurement data for CRNC to support TDD RRM | 270d? | 2002-12-06 A | 2003-12-18 A | 100% |  | 2002-12-06 | 2003-09-19 | 206d? |  | finish no earlier than 2003-09-19 | R3 | 2160h | 2160h | RANimp-RRMopt-FSUEMsD | Jim Miller, Interdigital | jim.miller@interdigital.com | Rel-6 | TSG |  |  |  |  |  |  |  |
| 41 | 9.4 | FS on the evolution of the UTRAN architecture | 395d | 2002-09-09 A | 2004-03-12 | 20% | 316d | 2002-09-09 | 2003-12-19 | 335d | 460d | finish no earlier than 2004-03-12 | R3 | 3160h | 632h | RANimp-FSEvo | Woonhee Hwang, Nokia | Antti.Toskala@nokia.com | Rel-6 | TSG | MCC_RAN |  |  |  |  |  |  |
| 42 | 8 | **PS domain and IMS impacts for supporting IMS Emergency calls** | 1013d? | 2000-08-14 A | 2004-06-30 | 33% | 676.09d? | 2000-08-14 | 2003-12-12 | 870d? | 382d |  | S2 | 38544h | 11170.2h | EMC1 | Rainer Liebhart |  | Rel-6 | TSG |  |  |  |  |  |  |  |
| 43 | 10.1.1 | Service Requirements for IP-based emergency calls | 725d | 2000-09-18 A | 2003-06-27 | 90% | 72.5d | 2000-09-18 | 2003-06-27 | 725d | 645d | finish no earlier than 2003-06-27 | S1 | 5800h | 5220h |  |  |  | Rel-6 |  |  | 1314 | CCaR | 22.976 |  |  |  |
| 44 | 8.2 | Stage 2 | 351d? | 2003-02-26 A | 2004-06-30 | 57% | 150.93d? | 2003-02-26 | 2003-09-18 | 147d? | 382d | finish no earlier than 2004-06-30 | S2 | 2808h | 1600.56h |  | Miikka Poikselka, Nokia |  | Rel-6 | TSG |  |  |  |  |  |  |  |
| 45 | 10.1 | **Emergency Call Enhancements for IP& PS Based Calls – stage 3** | 995d | 2000-08-14 A | 2004-06-04 | 8% | 917.28d | 2000-08-14 | 2003-12-12 | 870d | 400d |  | N1 | 22032h | 1720.85h |  | Mr Atle Monrad, Ericsson | Atle.Monrad@eto.ericsson.se | Rel-6 |  |  | 1653 | CCaR |  |  |  |  |
| 46 | 10.1.2 | SIP emergency calls and packet emergency calls signalling flows | 949d | 2000-10-17 A | 2004-06-04 | 16% | 797.16d | 2000-10-17 | 2003-12-12 | 824d | 400d | finish no earlier than 2004-06-04 | N1 | 7592h | 1214.72h |  | Mr Atle Monrad, Ericsson | Atle.Monrad@eto.ericsson.se | Rel-6 |  |  | 1315 | CCaR | TS 24.228 |  |  |  |
| 47 | 10.1.5 | Stage 3 for emergency calls and packet emergency calls in general | 995d | 2000-08-14 | 2004-06-04 |  |  | 2000-08-14 | 2003-12-12 | 870d | 400d | finish no earlier than 2004-06-04 | N1 | 7960h |  |  | Mr Atle Monrad, Ericsson | Atle.Monrad@eto.ericsson.se | Rel-6 |  |  | 1646 | CCaR | TS 24.229 |  |  |  |
| 48 | 12 | **Location Services enhancements 2** | 1003d? | 2000-08-28 A | 2004-06-30 | 61% | 389.35d? | 2000-08-28 | 2004-03-19 | 930d? | 382d |  | S2 | 77664h | 44802h | LCS2 |  |  | Rel-6 | TSG | Sang-Ui |  |  |  |  |  |  |
| 49 | 12.1 | **Improvement on Le interface** | 397d? | 2002-06-17 A | 2003-12-23 | 74% | 104.98d? | 2002-06-17 | 2003-12-23 | 397d? | 518d |  | S2 | 6776h | 4984.12h |  |  |  | Rel-6 | TSG |  |  |  |  |  |  |  |
| 50 | 9.1.1 | Stage 2 | 331d? | 2002-06-17 A | 2003-09-22 A | 100% |  | 2002-06-17 | 2003-09-22 | 331d? |  | start no earlier than 2002-06-17 | S2 | 2648h | 2648h |  |  |  | Rel-6 |  |  |  |  |  |  |  |  |
| 51 | 9.1.2 | Stage 3 in OMA - it impacts Mobile Location Protocol (MLP) | 119d? | 2003-07-10 | 2003-12-23 |  |  | 2003-07-10 | 2003-12-23 | 119d? | 518d | finish no earlier than 2003-12-23 | OMA | 952h |  |  |  |  | Rel-6 |  |  |  |  |  |  |  |  |

Notes:
- 31: Generic feature
- 32: This is a building block without particular end date

| ID | WBS | Task | Duration | Start | Finish | Complete | Remaining | Baseline start | Baseline finish | Baseline duration | Total slack | Constraint | Resources | Work | Actual work | Text6 | Text7 | Text1 | Text8 | Text4 | Text5 | Text9 |
| --- | --- | --- | --- | --- | --- | --- | --- | --- | --- | --- | --- | --- | --- | --- | --- | --- | --- | --- | --- | --- | --- | --- |
| 52 | 12.2 | **Enhanced support for anonymity and user privacy** | 382d? | 2002-07-08 A | 2003-12-23 | 68% | 121.55d? | 2002-07-08 | 2003-12-23 | 382d? | 518d |  | S2 | 6048h | 4072.03h | Rel-6 | TSG |  |  |  |  |  |
| 53 | 9.2.1 | Stage 2 | 255d? | 2002-07-08 A | 2003-06-27 A | 100% |  | 2002-07-08 | 2003-06-27 | 255d? |  | finish no earlier than 2003-06-27 | S2 | 2040h | 2040h | Rel-6 |  |  |  |  |  |  |
| 54 | 9.2.2 | Stage 3 in OMA (it impacts MLP and RLP) | 119d? | 2003-07-10 | 2003-12-23 |  |  | 2003-07-10 | 2003-12-23 | 119d? | 518d | finish no earlier than 2003-12-23 | OMA | 952h |  | Rel-6 |  |  |  |  |  |  |
| 55 | 12.3 | **Enhanced inter-GMLC interface** | 320d? | 2002-06-24 A | 2003-09-12 | 76% | 75.82d? | 2002-06-24 | 2003-09-12 | 320d? | 590d |  | S2 | 7240h | 5524.68h | Rel-6 | TSG |  |  |  |  |  |
| 56 | 9.3.1 | Stage 2 | 315d? | 2002-06-24 A | 2003-09-05 | 86% | 44.1d? | 2002-06-24 | 2003-09-05 | 315d? | 595d | finish no earlier than 2003-09-05 | S2 | 2520h | 2167.2h | Rel-6 |  |  |  |  |  |  |
| 57 | 9.3.2 | Stage 3 in OMA (definition of RLP and PCP) | 270d? | 2002-09-02 A | 2003-09-12 | 65% | 94.5d? | 2002-09-02 | 2003-09-12 | 270d? | 590d | finish no earlier than 2003-09-12 | OMA | 2160h | 1404h | Rel-6 |  |  |  |  |  |  |
| 58 | 12.4 | **Location Services support for IMS public identities** | 478d? | 2002-09-02 A | 2004-06-30 | 54% | 219.61d? | 2002-09-02 | 2003-12-19 | 340d? | 382d |  | S2 | 8368h | 4523.43h | Rel-6 | TSG |  |  |  |  |  |
| 59 | 9.4.1 | Stage 2 | 353d? | 2003-02-24 A | 2004-06-30 | 57% | 151.79d? | 2003-02-24 | 2003-12-19 | 215d? | 382d | finish no earlier than 2004-06-30 | S2 | 2824h | 1609.68h | Rel-6 |  |  |  |  |  |  |
| 60 | 9.4.2 | Stage 3 in OMA (impacts MLP, RLP and PCP) | 340d? | 2002-09-02 A | 2003-12-19 | 51% | 166.6d? | 2002-09-02 | 2003-12-19 | 340d? | 520d | finish no earlier than 2003-12-19 | OMA | 2720h | 1387.2h | Rel-6 |  |  |  |  |  |  |
| 61 | 12.5 | **New area event for location service triggering reports** | 535d? | 2002-06-03 A | 2004-06-18 | 65% | 187.63d? | 2002-06-03 | 2003-12-22 | 406d? | 390d |  | S2 | 8896h | 5229.15h | Rel-6 | TSG |  |  |  |  |  |
| 62 | 9.5.1 | Stage 2 | 280d? | 2002-06-03 A | 2003-06-27 A | 100% |  | 2002-06-03 | 2003-06-27 | 280d? |  | finish no earlier than 2003-06-27 | S2 | 2240h | 2240h | Rel-6 |  |  |  |  |  |  |
| 63 | 9.5.2 | Stage 3 for UE-CN signalling | 182d? | 2003-10-09 A | 2004-06-18 | 52% | 87.36d? | 2003-07-10 | 2003-12-22 | 118d? | 390d | finish no earlier than 2004-06-18 | N4 | 1456h | 757.12h | Rel-6 |  |  |  |  |  |  |
| 64 | 9.5.3 | Stage 3 in OMA (impacts MLP, RLP and PCP) | 115d? | 2003-07-14 | 2003-12-19 |  |  | 2003-07-14 | 2003-12-19 | 115d? | 520d | finish no earlier than 2003-12-19 | OMA | 920h |  | Rel-6 |  |  |  |  |  |  |
| 65 | 12.6 | **FS on applicability of GALILEO for LCS** | 518d? | 2002-07-08 A | 2004-06-30 | 54% | 236.22d? | 2002-07-08 | 2004-03-19 | 445d? | 382d |  | S2 | 9248h | 3776.48h | Rel-6 |  |  |  |  |  |  |
| 66 | 9.6.1 | TR on Stage 2 (No contributions received, No feedback from other groups since May) | 518d? | 2002-07-08 A | 2004-06-30 | 67% | 170.94d? | 2002-07-08 | 2004-03-19 | 445d? | 382d | finish no earlier than 2004-06-30 | S2 | 4144h | 2776.48h | Rel-6 |  |  |  |  |  |  |
| 67 | 9.6.2 | GERAN review of the TR | 120d? | 2003-08-25 | 2004-02-06 |  |  | 2003-08-25 | 2003-12-12 | 80d? | 485d | finish no earlier than 2004-02-06 | GP | 960h |  | Rel-6 |  |  |  |  |  |  |
| 68 | 12.7 | **UE positioning** | 991d? | 2000-08-28 A | 2004-06-14 | 56% | 431.74d? | 2000-08-28 | 2004-03-19 | 930d? | 394d |  | RP | 24664h | 12761.8h | Rel-6 | TSG | LCS2-UEpos | MCC_RAN |  |  |  |
| 69 | 12.7.1 | UE positioning enhancements - other methods | 805d | 2000-08-28 A | 2003-09-26 | 10% | 724.5d | 2000-08-28 | 2003-09-26 | 805d | 580d | start no earlier than 2000-08-28 | R2 | 6440h | 644h | Rel-6 | TSG | LCS2-UEpos-enh | MCC_RAN | Meik Kottkamp, Siemens | Meik.Kottkamp@siemens.com | 2457 |
| 70 | 12.8 | Open SMLC-SRNC Interface within the UTRAN to support UTRAN Rel4 positioning methods | 700d? | 2001-01-15 A | 2003-09-19 A | 100% |  | 2001-01-15 | 2003-09-19 | 700d? |  | finish no earlier than 2003-09-19 | R2 | 5600h | 5600h | Rel-6 | TSG | LCS-Rel4Pos |  | Meik Kottkamp, Siemens | Meik.Kottkamp@siemens.com | 2475 |
| 71 | 9.7.3 | A-GPS minimum performance specification | 267d? | 2003-06-06 A | 2004-06-14 | 30% | 186.9d? | 2003-06-06 | 2004-03-19 | 206d? | 394d | finish no earlier than 2004-06-14 | R4 | 2136h | 640.8h | Rel-6 | TSG | LCS-UEPos-AGPSPerf | MCC_RAN | Donglin Shen, AT&T Wireless Services | donglin.shen@attws.com |  |
| 72 | 12.7.2 | FS on Enhancements to OTDOA Positioning using advanced blanking methods | 320d | 2002-07-01 A | 2003-09-19 A | 100% |  | 2002-07-01 | 2003-09-19 | 320d |  | finish no earlier than 2003-09-19 | R2 | 2560h | 2560h | Rel-6 | TSG | LCS2-UEpos-FSBlank |  | David Bartlett, Cambridge Positioning Systems | david.bartlett@cursor-system.com |  |
| 73 | 14 | **Security enhancements** | 813d? | 2001-01-03 A | 2004-02-13 | 43% | 462.41d? | 2001-01-03 | 2003-03-14 | 573d | 480d |  | S3 | 24736h | 9730.28h | Rel-6 | TSG | SEC1 | Maurice | Peter Howard, Vodafone | Peter.Howard@vodafone.com |  |
| 74 | 14.1 | **Enhanced HE control of security (including positive authentication reporting)** | 712d | 2001-01-03 A | 2003-09-25 | 23% | 545d | 2001-01-03 | 2003-03-14 | 573d | 581d |  | S3 | 14064h | 4008h | Rel-6 |  |  |  | Peter Howard, Vodafone | Peter.Howard@vodafone.com | 2026 |
| 75 | 14.1.1 | Stage 2 | 378d | 2001-01-03 | 2002-06-14 |  |  | 2001-01-03 | 2002-06-14 | 378d | 915d | finish no earlier than 2002-06-14 | S3 | 3024h |  | Rel-6 |  |  |  |  |  | 2027 |

Notes:
- 63: 31/10/2003 work has started. Current stage 3 fullfills the requirements of stage 2.
- 69: This is a building block without particular end date
- 73: Added BB UE authentication and rapporteur added.
- 74: Added by P-000575 without any dates. 18/10/00: Change of WI title, added hyperlink rapporteur new end date 03/01. New end date and correct Release to be decided S3#18
- 75: New end date and correct Release to be decided S3#18

| ID | WBS | Task | Duration | Start | Finish | Complete | Remaining | Baseline start | Baseline finish | Baseline duration | Total slack | Constraint | Resources | Work | Actual work | Text1 | Text2 | Text4 | Text5 | Text6 | Text7 | Text8 |
| --- | --- | --- | --- | --- | --- | --- | --- | --- | --- | --- | --- | --- | --- | --- | --- | --- | --- | --- | --- | --- | --- | --- |
| 76 | 14.1.3 | **Network domain security** | 334d | 2002-06-17 A | 2003-09-25 | 50% | 167d | 2002-06-17 | 2003-03-14 | 195d | 581d |  | S3 | 5344h | 2672h | SEC1-NDS | Sec | Geir M. Køien, Telenor | Geir-myrdahl.koien@telenor.com | Rel-6 | TSG |  |
| 77 | 14.1.3.1 | IP network layer security (NDS/IP) | 334d | 2002-06-17 A | 2003-09-25 | 50% | 167d | 2002-06-17 | 2003-03-14 | 195d | 581d | finish no earlier than 2003-09-25 | S3 | 2672h | 1336h | SEC1-NDS-IP |  |  |  | Rel-6 | WG |  |
| 78 | 10.2 | Network Domain Security; Authentication Framework (NDS/AF) | 521d? | 2002-02-15 A | 2004-02-13 | 70% | 156.3d? | 2002-02-15 | 2003-12-19 | 481d? | 480d | finish no earlier than 2004-02-13 | S3 | 4168h | 2917.6h | SEC1-NDS-AF |  | Tommi Viitanen, Nokia | tommi.viitanen@nokia.com | Rel-6 | TSG |  |
| 79 | 16 | **IMS Phase 2** | 995d? | 2000-08-28 A | 2004-06-18 | 54% | 462.26d? | 2000-08-28 | 2003-12-18 | 864d? | 390d |  | S1 | 114441h | 56600.1h | IMS2 |  |  |  | Rel-6 | TSG | Sang-Ui |
| 80 | 16.1 | Stage 2 of IMS Phase 2 | 275d | 2002-09-02 A | 2003-09-19 | 80% | 55d | 2002-09-02 | 2003-09-19 | 275d | 585d | finish no earlier than 2003-09-19 | S2 | 2200h | 1760h |  |  |  |  | Rel-6 |  |  |
| 81 | 11.2 | Enhancements to the Cx and Sh interfaces | 271d? | 2003-06-06 A | 2004-06-18 | 46% | 146.34d? | 2003-06-06 | 2003-12-12 | 136d? | 390d | finish no earlier than 2004-06-18 | N4 | 2168h | 997.28h | IMS2-CCR |  |  |  | Rel-6 | WG |  |
| 82 | 16.12 | **IMS Group Management** | 592d? | 2002-03-14 A | 2004-06-18 | 39% | 361.99d? | 2002-03-14 | 2003-12-12 | 457d? | 390d |  | S1 | 12160h | 4724.45h | IMSGM |  | Juha Kalliokulju (Nokia) | juha.kalliokulju@nokia.com | Rel-6 | TSG |  |
| 83 | 16.12.1 | Stage 1 - TS on IMS group management | 193d | 2002-03-14 A | 2002-12-09 A | 100% |  | 2002-03-14 | 2002-12-09 | 193d |  | finish no earlier than 2002-12-09 | S1 | 1544h | 1544h |  |  | Juha Kalliokulju (Nokia) | juha.kalliokulju@nokia.com | Rel-6 | TSG |  |
| 84 | 11.3.2 | Stage 2 | 158d? | 2003-05-26 A | 2003-12-31 A | 100% |  | 2003-05-26 | 2003-09-23 | 87d? |  | finish no earlier than 2003-12-31 | S2 | 1264h | 1264h |  |  |  |  | Rel-6 |  |  |
| 85 | 11.3.3 | Stage 3 for IMS Group management (e.g. chat) | 386d? | 2002-12-13 | 2004-06-04 |  |  | 2002-12-13 | 2003-12-12 | 261d? | 400d | finish no earlier than 2004-06-04 | N1 | 3088h |  |  |  | Keith Drage, Lucent | drage@lucent.com |  |  |  |
| 86 | 11.3.4 | Key Management of group keys for Voice Group Call Services | 191d | 2003-09-26 A | 2004-06-18 | 5% | 181.45d |  |  |  | 390d | finish no earlier than 2004-06-18 | S3 | 1528h | 76.4h | SECGKYV |  | Benno Tietz, Vodafone D2 | benno.tietz@vodafone.com | Rel-6 | TSG | Maurice |
| 87 | 11.4 | **IMS Conferencing** | 415d? | 2002-11-04 A | 2004-06-04 | 80% | 82.52d? | 2002-11-04 | 2003-12-12 | 290d? | 400d |  | N1 | 8832h | 7075.73h |  |  |  |  | Rel-6 |  |  |
| 88 | 11.4.1 | Stage 2 | 303d? | 2002-11-04 A | 2003-12-31 | 93% | 21.21d? | 2002-11-04 | 2003-09-26 | 235d? | 512d | finish no earlier than 2003-12-31 | S2 | 2424h | 2254.32h |  |  |  |  | Rel-6 |  |  |
| 89 | 11.4.2 | Stage 3 | 386d? | 2002-12-13 A | 2004-06-04 | 70% | 115.8d? | 2002-12-13 | 2003-12-12 | 261d? | 400d | finish no earlier than 2004-06-04 | N1 | 3088h | 2161.6h |  |  | Keith Drage, Lucent | drage@lucent.com |  |  |  |
| 90 | 16.11 | **IMS Messaging** | 582d? | 2002-03-14 A | 2004-06-04 | 68% | 187.02d? | 2002-03-14 | 2003-12-12 | 457d? | 400d |  | S1 | 14520h | 9854.05h | IMSM |  | Juha Kalliokulju (Nokia) | juha.kalliokulju@nokia.com | Rel-6 | TSG |  |
| 91 | 16.11.1 | TR on support of messaging in the IMS | 193d | 2002-03-14 A | 2002-12-09 A | 100% |  | 2002-03-14 | 2002-12-09 | 193d |  | finish no earlier than 2002-12-09 | S1 | 1544h | 1544h | IMSM-TR |  | Juha Kalliokulju (Nokia) | juha.kalliokulju@nokia.com | Rel-6 | TSG |  |
| 92 | 11.5.2 | Stage 1 22.340 | 23d? | 2002-11-11 A | 2002-12-11 A | 100% |  | 2002-11-11 | 2002-12-11 | 23d? |  | finish no earlier than 2002-12-11 | S1 | 184h | 184h | IMSM-TS |  | Juha Kalliokulju (Nokia) | juha.kalliokulju@nokia.com | Rel-6 | TSG |  |
| 93 | 11.5.3 | CRs to 22.140 & 22.228 | 263d? | 2002-03-14 A | 2003-03-17 A | 100% |  | 2002-03-14 | 2003-03-17 | 263d? |  | finish no earlier than 2003-03-17 | S1 | 2104h | 2104h | IMSM-CR |  | Juha Kalliokulju (Nokia) | juha.kalliokulju@nokia.com | Rel-6 | TSG |  |
| 94 | 16.11.3 | Stage 2 | 368d | 2002-11-04 A | 2004-03-31 | 71% | 106.72d | 2002-11-04 | 2003-09-26 | 235d | 447d | finish no earlier than 2004-03-31 | S2 | 2944h | 2090.24h |  |  |  |  | Rel-6 |  |  |
| 95 | 11.5.5 | Stage 3 for IMS Messaging | 386d? | 2002-12-13 A | 2004-06-04 | 25% | 289.5d? | 2002-12-13 | 2003-12-12 | 261d? | 400d | finish no earlier than 2004-06-04 | N1 | 3088h | 772h |  |  | Keith Drage, Lucent | drage@lucent.com |  |  |  |
| 96 | 16.7 | **IMS Local services** | 895d? | 2001-01-01 A | 2004-06-04 | 46% | 485.89d? | 2001-01-01 | 2003-12-12 | 770d? | 400d |  | S2 | 12848h | 5192.02h |  |  |  |  | Rel-6 |  |  |
| 97 | 16.7.1 | Stage 2 | 325d | 2001-01-01 A | 2002-03-29 A | 100% |  | 2001-01-01 | 2002-03-29 | 325d |  | start no earlier than 2001-01-01 | S2 | 2600h | 2600h |  |  |  |  | Rel-6 |  |  |
| 98 | 11.6.2 | Stage 3 for IMS Local services | 386d? | 2002-12-13 | 2004-06-04 |  |  | 2002-12-13 | 2003-12-12 | 261d? | 400d | finish no earlier than 2004-06-04 | N1 | 3088h |  |  |  | Keith Drage, Lucent | drage@lucent.com |  |  |  |
| 99 | 11.7 | **Additional SIP Capabilities support not covered by Rel-5** | 410d? | 2002-11-11 A | 2004-06-04 | 45% | 225.47d? | 2002-11-11 | 2003-12-12 | 285d? | 400d |  | N1 | 8752h | 3939.04h |  |  |  |  | Rel-6 |  |  |
| 100 | 11.7.1 | Stage 2 for add SIP cap (e.g. forking) | 298d? | 2002-11-11 A | 2003-12-31 | 51% | 144.55d? | 2002-11-11 | 2003-06-27 | 165d? | 512d | start no earlier than 2002-11-11 | S2 | 2384h | 1227.6h |  |  |  |  | Rel-6 |  |  |
| 101 | 11.7.2 | Stage 3 for Additional SIP Capabilities | 386d? | 2002-12-13 A | 2004-06-04 | 40% | 231.6d? | 2002-12-13 | 2003-12-12 | 261d? | 400d | finish no earlier than 2004-06-04 | N1 | 3088h | 1235.2h |  |  | Keith Drage, Lucent | drage@lucent.com |  |  |  |
| 102 | 11.8 | Review additional SIP Capabilities against IMS | 326d? | 2002-12-13 A | 2004-03-12 | 20% | 260.8d? | 2002-12-13 | 2003-12-12 | 261d? | 460d | finish no earlier than 2004-03-12 | N1 | 2608h | 521.6h |  |  | Keith Drage, Lucent | drage@lucent.com |  |  |  |

Notes:
- 76: WID approved for Rel-6 at SA#17
- 77: Should be complete after SA3#27 / Text3: TS 33.210
- 78: WID approved SA#19. Work started after FS approved SA#18
- 79: Not yet available: verbally approved at SA15, actual WID to be provided at SA16 by Lucent
- 81: 29/05/2003 CN4: New WID presented for approval at CN#20......
- 86: Approved TSG#21 / Text3: 42.068, 43.068, 44.068, 42.069, 43.069, 44.069, 31.102, 24.008, 48.008, 42.009, 43.020
- 92: Text3: 22.340
- 93: Text3: 22.140,22.228
- 96: Text3: 23.228

| ID | WBS | Task | Duration | Start | Finish | Complete | Remaining | Baseline start | Baseline finish | Baseline duration | Total slack | Constraint | Resources | Work | Actual work | Text1 | Text2 | Text3 | Text4 | Text5 | Text6 | Text7 | Text9 | Text8 |
| --- | --- | --- | --- | --- | --- | --- | --- | --- | --- | --- | --- | --- | --- | --- | --- | --- | --- | --- | --- | --- | --- | --- | --- | --- |
| 103 | 16.5 | **Interworking between IMS and IP networks** | 860d | 2000-08-28 A | 2003-12-12 | 57% | 372.13d | 2000-08-28 | 2003-12-12 | 860d | 525d |  | N3 | 19600h | 9336h | IMS-CCR-IWIP | BaAS | 23.821, 29.061, 29.162 | Nigel Holland, BT | nigel.holland@bt.com | Rel-6 | TSG | 2048 |  |
| 104 | 16.5.1 | Interworking for 3GPP_SIP and IETF_SIP | 730d | 2000-08-28 A | 2003-06-13 A | 100% |  | 2000-08-28 | 2003-12-12 | 860d |  | finish no earlier than 2003-06-13 | N3 | 5840h | 5840h |  |  | New TR 29.962 | Thomas Belling, Siemens |  | Rel-6 |  |  |  |
| 105 | 16.5.2 | Interworking for IPv6 to IPv4 | 860d | 2000-08-28 A | 2003-12-12 | 20% | 688d | 2000-08-28 | 2003-12-12 | 860d | 525d | finish no earlier than 2003-12-12 | N3 | 6880h | 1376h |  |  | 29.163 |  |  | Rel-6 |  |  |  |
| 106 | 16.8 | **Mm interface (CSCF to external IP multimedia network) -- NOT CN3** | 843d | 2001-03-14 A | 2004-06-04 | 40% | 505.8d | 2001-03-14 | 2003-12-12 | 718d | 400d |  | N1 | 11305.3h | 2697.6h |  |  |  |  |  | Rel-6 |  |  |  |
| 107 | 16.8.1 | CN1 part | 843d | 2001-03-14 A | 2004-06-04 | 40% | 505.8d | 2001-03-14 | 2003-12-12 | 718d | 400d | finish no earlier than 2004-06-04 | N1 | 6744h | 2697.6h |  |  |  |  |  | Rel-6 |  |  |  |
| 108 | 16.6.1 | Interworking between IMS and CS networks | 929d? | 2000-08-28 A | 2004-03-18 | 78% | 209d? | 2000-08-28 | 2003-09-05 | 790d? | 456d | finish no earlier than 2004-03-18 | N3 | 7432h | 5760h | IMS-CCR-IWCS | CCaR | 29.163, 29.061, 24.228, and new CN4 specification | Brendan Mc Williams, Vodafone | brendan.mcwilliams@vf.vodafone.co.uk | Rel-6 | TSG |  |  |
| 109 | 16.10 | Mn interface (IM-MGW to MGCF) enhancements (CN3 Part) | 365d | 2001-08-07 A | 2004-06-18 | 45% | 200.75d | 2002-09-02 | 2003-12-12 | 335d | 390d | start no earlier than 2001-08-07 | N4 | 2920h | 1314h | IMS-CCR-Mn |  |  |  |  | Rel-6 |  |  |  |
| 110 | 11.13 | Mp (MRFC - MRFP) interface (CN3 Part) | 248d | 2003-07-09 | 2004-06-18 |  |  | 2002-10-07 | 2003-12-12 | 310d | 390d | finish no earlier than 2004-06-18 | N4 | 1984h |  | IMS-CCR-Mp |  |  |  |  | Rel-6 |  |  |  |
| 111 | 11.14 | Study of subscriber and operators relationship in IMS and related ISIM requirements for Rel 6” | 20d? | 2002-11-15 A | 2002-12-12 A | 100% |  | 2002-11-15 | 2002-12-12 | 20d? |  | finish no earlier than 2002-12-12 | S1 | 160h | 160h |  |  |  | Juha Kalliokulju (Nokia) | juha.kalliokulju@nokia.com | Rel-6 |  |  |  |
| 112 | 11.15 | Lawful Interception in the 3GPP Rel-6 architecture | 269d? | 2002-12-09 A | 2003-12-18 | 10% | 242.1d? | 2002-12-09 | 2003-12-18 | 269d? | 521d | finish no earlier than 2003-12-18 | S3 | 2152h | 215.2h | SEC1-LI |  | 33.106, 33.107, 33.108 | Berthold Wilhelm | Berthold.Wilhelm@REGTP.DE | Rel-6 | TSG |  |  |
| 113 | 11.16 | IMS Subscription and access scenarios | 130d? | 2002-12-16 A | 2003-06-13 A | 100% |  | 2002-12-16 | 2003-06-13 | 130d? |  | start no earlier than 2002-12-16 | S1 | 1040h | 1040h |  |  | 22.800 |  |  | Rel-6 |  |  |  |
| 114 | 12 | 3GPP Enablers for services like Push to Talk over Cellular (PoC) | 210d? | 2003-09-08 A | 2004-06-25 | 29% | 148.23d? |  |  |  | 385d |  | S2 | 1680h | 494.16h |  |  | 23.9xx | Shabnam Sultana, Ericsson |  | Rel-6 |  |  |  |
| 115 | 13 | Interworking aspects and migration scenarios for IPv4 based IMS Implementations (Study) | 210d? | 2003-09-08 A | 2004-06-25 | 29% | 149.1d? |  |  |  | 385d | finish no earlier than 2004-06-25 | S2 | 1680h | 487.2h |  |  |  | Alexander Milinski, Siemens |  | Rel-6 |  |  |  |
| 116 | 16.3 | **Interoperability and Commonality between IMS using different "IP-connectivity Networks"** | 325d? | 2002-09-16 A | 2003-12-12 | 96% | 14.29d? | 2002-09-16 | 2003-12-12 | 325d | 525d |  | S2 | 9176h | 6439.92h | IMSCOOP |  |  |  |  | Rel-6 | TSG |  | Sang-Ui |
| 117 | 16.3.1 | Stage 2 for Interoperability (no contributions assumed that no more will be done in 3GPP hence work may need to be done in pp2) | 272d | 2002-09-16 A | 2003-09-30 | 92% | 21.76d | 2002-09-16 | 2003-09-19 | 265d | 578d | finish no earlier than 2003-09-30 | S2 | 2176h | 2001.92h |  |  |  | Balazs Beternyi, Nokia |  | Rel-6 |  |  |  |
| 118 | 14.2 | Stage 2 for commonality | 265d? | 2002-09-16 A | 2003-09-19 A | 100% |  | 2002-09-16 | 2003-09-19 | 265d? |  | start no earlier than 2002-09-16 | S2 | 2120h | 2120h |  |  |  | Balazs Beternyi, Nokia |  | Rel-6 |  |  |  |
| 119 | 16.3.2 | Stage 3 | 305d | 2002-10-14 A | 2003-12-12 | 95% | 15.25d | 2002-10-14 | 2003-12-12 | 305d | 525d | finish no earlier than 2003-12-12 | N1 | 2440h | 2318h |  |  |  | Keith Drage, Lucent | drage@lucent.com | Rel-6 |  |  |  |
| 120 | 17 | **Support of Push Services** | 823d | 2001-01-03 A | 2004-02-27 | 93% | 59.34d | 2001-01-03 | 2003-12-26 | 778d | 470d |  | S1 | 12814.6h | 6651.2h | PUSH | CCaR |  | Yoshinori Kitada, NTT Comware |  | Rel-6 | TSG | 1365 | Sang-Ui |
| 121 | 17.1 | Stage 1 | 378d | 2001-01-03 A | 2002-06-14 A | 100% |  | 2001-01-03 | 2002-06-14 | 378d |  | finish no earlier than 2002-06-14 | S1 | 3024h | 3024h |  |  |  |  |  | Rel-6 |  |  |  |
| 122 | 17.2 | MOVE TO REL5- TR on feasibility study | 178d | 2001-01-03 A | 2001-09-07 A | 100% |  | 2001-01-03 | 2001-09-07 | 178d |  | finish no earlier than 2001-09-07 | S2 | 1424h | 1424h |  |  |  |  |  | Rel-6 |  |  |  |
| 123 | 17.3 | TR 23.976 on Push Architecture | 340d | 2002-11-11 A | 2004-02-27 | 81% | 64.6d | 2002-11-11 | 2003-12-26 | 295d | 470d | finish no earlier than 2004-02-27 | S2 | 2720h | 2203.2h |  |  |  | Nick Alfano, RIM |  | Rel-6 |  |  |  |
| 124 | 18 | **Multimedia Messaging (MMS) enhancements** | 472d? | 2002-08-15 A | 2004-06-04 | 36% | 303.1d? | 2002-08-15 | 2004-03-10 | 410d? | 400d |  | T2 | 20296h | 8732.01h | MMS6 | Mes |  | Josef Laumen, Siemens | Josef.Laumen@SAL.SIEMENS.DE | Rel-6 | TSG |  | Friedhelm |
| 125 | 18.1 | **Definition of service requirements** | 286d? | 2002-11-15 A | 2003-12-19 A | 100% |  | 2002-11-15 | 2003-12-20 | 286d? |  |  | S1 | 4576h | 4576h | MMS6-SR |  | 22.140 |  |  | Rel-6 |  |  |  |
| 126 | 16.1.1 | Definition of service requirements charging | 286d? | 2002-11-15 A | 2003-12-19 A | 100% |  | 2002-11-15 | 2003-12-20 | 286d? |  | finish no earlier than 2003-12-20 | S1 | 2288h | 2288h |  |  | 22.140 | Josef Laumen, Siemens | Josef.Laumen@SAL.SIEMENS.DE | Rel-6 |  |  |  |
| 127 | 18.2 | Technical realization | 410d | 2002-08-15 A | 2004-03-10 | 45% | 225.5d | 2002-08-15 | 2003-12-10 | 345d | 462d | finish no earlier than 2004-03-10 | T2 | 3280h | 1476h |  |  | 23.140 | Josef Laumen, Siemens | Josef.Laumen@SAL.SIEMENS.DE | Rel-6 | TSG |  | Friedhelm |
| 128 | 18.3 | OMA dependencies | 410d | 2002-08-15 A | 2004-03-10 | 10% | 369d | 2002-08-15 | 2004-03-10 | 410d | 462d | finish no earlier than 2004-03-10 | T2 | 3280h | 328h |  |  |  |  |  | Rel-6 |  |  | Friedhelm |
| 129 | 18.4 | MMS formats and codecs | 417d | 2002-08-15 A | 2004-03-19 | 30% | 291.9d | 2002-08-15 | 2003-12-18 | 351d | 455d | finish no earlier than 2004-03-19 | S4 | 3336h | 1000.8h |  |  | 26.140 |  |  | Rel-6 |  |  | Paolo |
| 130 | 16.5 | Handling of private addressing schemes in MMS | 128d | 2003-12-10 | 2004-06-04 |  |  |  |  |  | 400d | start no earlier than 2003-12-10 | T2 | 1024h |  |  |  | 23.140 | Matthias Röbke, T-Mobile | Matthias.Roebke@t-mobile.de | Rel-6 | TSG |  | Friedhelm |
| 131 | 16.6 | FS Multiple MMS Relay/Server Architecture | 128d | 2003-12-10 | 2004-06-04 |  |  |  |  |  | 400d | start no earlier than 2003-12-10 | T2 | 1024h |  |  |  | new TR | Juan Gorospe, Telefónica Móviles | gorospe_j@tsm.es | Rel-6 | TSG |  | Friedhelm |

Notes:
- 103: [DAB 14.02.02] - end date pushed back to March 2003
- 104: [DAB - 20.08.03] - CN Part of TR Complete @ CN#20
- 106: [DAB - 23.05.03] - IS NOT THE RESPO OF CN3
- 108: [DAB - 23.05.03] - Remove ITU dependancies
- 109: [CN4] 17th May 2002, CN4; Will be handled in Rel-6...
- 110: 27/11/2002 KK: WID approved at CN#18 (NP-020601) / 27/11/2002CN4: Target will be CN#20 / 29/05/2003 CN4: No change at CN4#19 / 31/10/2003 CN4: target will be CN4#24
- 120: AS: Changed from FS to actual support of Push
- 122: Stage 2 on hold, waiting for requirements.

| ID | WBS | Task | Duration | Start | Finish | Complete | Remaining | Baseline start | Baseline finish | Baseline duration | Total slack | Constraint | Resources | Work | Actual work | Text1 | Text2 | Text6 | Text7 | Text8 | Text3 | Text4 | Text5 | Text9 |
| --- | --- | --- | --- | --- | --- | --- | --- | --- | --- | --- | --- | --- | --- | --- | --- | --- | --- | --- | --- | --- | --- | --- | --- | --- |
| 132 | 19 | **Rel-6 MExE enhancements** | 326d | 2002-03-08 A | 2003-06-06 A | 100% |  | 2002-03-08 | 2003-06-06 | 326d |  |  | T2 | 7328h | 7328h | MEXE6 | Ter | Rel-6 | TSG | Friedhelm |  |  |  |  |
| 133 | 19.1 | MExE Rel-6 Improvements and Investigations | 264d | 2002-03-08 A | 2003-03-12 A | 100% |  | 2002-03-08 | 2003-03-12 | 264d |  | finish no earlier than 2003-03-12 | T2 | 2112h | 2112h | MEXE6-ENHANC | Ter | Rel-6 | TSG |  | 22.057, 23.057 | Lars Brenk (TTPCom) | lsb_ttpcom@HOTMAIL.COM |  |
| 134 | 19.2 | MExE Run-Time Independent Framework Feasibility Study | 326d | 2002-03-08 A | 2003-06-06 A | 100% |  | 2002-03-08 | 2003-06-06 | 326d |  | finish no earlier than 2003-06-06 | T2 | 2608h | 2608h | MEXE6-RTIF | Ter | Rel-6 | TSG |  | 22.857 | Aaron Cohen (Intel) | Aaron.Cohen@intel.com |  |
| 135 | 21 | Subscription Management | 456d | 2002-09-20 A | 2004-06-18 | 65% | 159.6d | 2000-12-29 | 2004-03-19 | 841d | 390d | finish no earlier than 2004-01-15 | S5 | 3648h | 2371.2h | SM |  | Rel-6 | TSG | Adrian | 32.140/1, 32.171/2 | Istvan ABA (T-Mobile Austria) | istvan.aba@t-mobile.at |  |
| 136 | 22 | **Support of Presence Capability** | 785d? | 2001-03-19 A | 2004-03-19 | 76% | 191.31d? | 2001-03-19 | 2003-12-19 | 720d? | 455d |  | S1 | 20264h | 15325.5h | PRESNC |  | Rel-6 | TSG | Michael |  | Mark Cataldo, Motorola |  | 11004 |
| 137 | 22.1 | Stage 1 | 610d | 2001-03-19 A | 2003-07-18 A | 100% |  | 2001-03-19 | 2003-07-18 | 610d |  | finish no earlier than 2003-07-18 | S1 | 4880h | 4880h |  |  | Rel-6 |  |  |  |  |  | 11005 |
| 138 | 22.2 | Stage 2 | 268d | 2001-09-12 A | 2002-09-20 A | 100% |  | 2001-09-12 | 2002-09-20 | 268d |  | finish no earlier than 2002-09-20 | S2 | 2144h | 2144h |  |  | Rel-6 | TSG |  |  |  |  |  |
| 139 | 22.3 | Stage 3 | 510d | 2002-04-01 A | 2004-03-12 | 80% | 102d | 2002-04-01 | 2003-12-19 | 450d | 460d | finish no earlier than 2004-03-12 | N1 | 4080h | 3264h |  |  | Rel-6 |  |  |  | Keith Drage, Lucent | drage@lucent.com |  |
| 140 | 19.4 | Media Codecs and Formats for IMS Messaging and Presence | 202d? | 2003-06-12 A | 2004-03-19 | 10% | 181.8d? | 2003-06-12 | 2003-12-18 | 136d? | 455d | finish no earlier than 2004-03-19 | S4 | 1616h | 161.6h | COFIMP |  | Rel-6 | TSG | Paolo | TS 26.141 | Harri Honko (Nokia) | harri.honko@nokia.com |  |
| 141 | 22.4 | Security issues | 79d | 2002-08-26 A | 2002-12-12 | 20% | 63.2d | 2002-08-26 | 2002-12-12 | 79d | 786d | finish no earlier than 2002-12-12 | S3 | 632h | 126.4h |  |  | Rel-6 |  |  |  |  |  |  |
| 142 | 22.5 | USIM issues | 79d | 2002-03-04 | 2002-06-20 |  |  | 2002-03-04 | 2002-06-20 | 79d | 911d | start no earlier than 2002-03-04 | T3 | 632h |  |  |  | Rel-6 |  |  |  |  |  |  |
| 143 | 25 | **Enhanced A/Gb feasibility study** | 51d? | 2002-08-30 A | 2002-11-08 | 75% | 12.75d? | 2002-08-30 | 2002-11-08 | 51d? | 810d |  | GP | 4080h | 3162h | AGbEnFS |  | Rel-6 | TSG | Paolo |  | J-L Carrizo, Vodafone | jose-luis.carrizo@vodafone.co.uk |  |
| 144 | 25.1 | **Feasibility study on A/Gb enhancements** | 51d? | 2002-08-30 A | 2002-11-08 | 75% | 12.75d? | 2002-08-30 | 2002-11-08 | 51d? | 810d |  | G2 | 3672h | 2856h | AGbEnFS-FS |  | Rel-6 | TSG |  |  |  |  |  |
| 145 | 25.1.1 | Requirements for the support of conversational services | 51d | 2002-08-30 A | 2002-11-08 A | 100% |  | 2002-08-30 | 2002-11-08 | 51d |  | finish no earlier than 2002-11-08 | GP | 408h | 408h |  |  | Rel-6 |  |  |  |  |  |  |
| 146 | 20.1.2 | Identification of the different building blocks for the provision of conversational services on the existing A/Gb protocol stack | 51d? | 2002-08-30 A | 2002-11-08 A | 100% |  | 2002-08-30 | 2002-11-08 | 51d? |  | finish no earlier than 2002-11-08 | GP | 408h | 408h |  |  | Rel-6 |  |  |  |  |  |  |
| 147 | 20.1.3 | Outline of impact and feasibility of these building blocks and their different solutions | 51d? | 2002-08-30 A | 2002-11-08 A | 100% |  | 2002-08-30 | 2002-11-08 | 51d? |  | finish no earlier than 2002-11-08 | GP | 408h | 408h |  |  | Rel-6 |  |  |  |  |  |  |
| 148 | 25.1.2 | Identification of the different building blocks for the provision of conversational services on the existing A/Gb protocol stack | 51d | 2002-08-30 | 2002-11-08 |  |  | 2002-08-30 | 2002-11-08 | 51d | 810d | finish no earlier than 2002-11-08 | G2 | 408h |  |  |  | Rel-6 |  |  |  |  |  |  |
| 149 | 25.1.3 | Outline of impact and feasibility of these building blocks and their different solutions | 51d | 2002-08-30 | 2002-11-08 |  |  | 2002-08-30 | 2002-11-08 | 51d | 810d | finish no earlier than 2002-11-08 | G2 | 408h |  |  |  | Rel-6 |  |  |  |  |  |  |
| 150 | 25.1.4 | Impact on 3GPP architecture and requirement to co-ordinatge with other TSGs (CN, SA) | 51d | 2002-08-30 A | 2002-11-08 A | 100% |  | 2002-08-30 | 2002-11-08 | 51d |  | finish no earlier than 2002-11-08 | GP | 408h | 408h |  |  | Rel-6 |  |  |  |  |  |  |
| 151 | 25.1.5 | Standardisation effort | 51d | 2002-08-30 A | 2002-11-08 A | 100% |  | 2002-08-30 | 2002-11-08 | 51d |  | finish no earlier than 2002-11-08 | GP | 408h | 408h |  |  | Rel-6 |  |  |  |  |  |  |
| 152 | 25.1.6 | Dependency to other features | 51d | 2002-08-30 A | 2002-11-08 A | 100% |  | 2002-08-30 | 2002-11-08 | 51d |  | finish no earlier than 2002-11-08 | GP | 408h | 408h |  |  | Rel-6 |  |  |  |  |  |  |
| 153 | 26 | **Flexible Layer One for GERAN** | 1170d | 2000-01-03 A | 2004-06-25 | 86% | 169.13d | 2000-01-03 | 2003-11-21 | 1015d | 385d |  | GP | 70903h | 46083.7h | FLOGER |  | Rel-6 | TSG | Paolo |  | Benoist Sébire | benoist.sebire@nokia.com |  |
| 154 | 26.1 | **Realisation of a Flexible Layer One** | 1070d | 2000-01-03 A | 2004-02-06 | 90% | 107d | 2000-01-03 | 2003-06-27 | 910d | 485d |  | GP | 39728h | 30963.2h | FLOGER-Real |  | Rel-6 |  |  |  | Benoist Sébire | benoist.sebire@nokia.com |  |
| 155 | 26.1.1 | Technical Report | 471d | 2002-04-19 A | 2004-02-06 | 90% | 47.1d | 2002-04-19 | 2003-06-27 | 311d | 485d | finish no earlier than 2004-02-06 | GP | 3768h | 3391.2h |  |  | Rel-6 |  |  |  |  |  |  |
| 156 | 26.1.2 | Architecture in 45.001 and 43.051 | 471d | 2002-04-19 A | 2004-02-06 | 90% | 47.1d | 2002-04-19 | 2003-06-27 | 311d | 485d | finish no earlier than 2004-02-06 | G1 | 3768h | 3391.2h |  |  | Rel-6 |  |  |  |  |  |  |
| 157 | 26.1.3 | Multiplexing in 45.002 | 471d | 2002-04-19 A | 2004-02-06 | 90% | 47.1d | 2002-04-19 | 2003-06-27 | 311d | 485d | finish no earlier than 2004-02-06 | G1 | 3768h | 3391.2h |  |  | Rel-6 |  |  |  |  |  |  |
| 158 | 26.1.4 | Channel Coding in 45.003 | 471d | 2002-04-19 A | 2004-02-06 | 90% | 47.1d | 2002-04-19 | 2003-06-27 | 311d | 485d | finish no earlier than 2004-02-06 | G1 | 3768h | 3391.2h |  |  | Rel-6 |  |  |  |  |  |  |
| 159 | 26.1.5 | Performance Requirements in 45.005 | 1070d | 2000-01-03 A | 2004-02-06 | 90% | 107d | 2000-01-03 | 2003-06-27 | 910d | 485d | finish no earlier than 2004-02-06 | G1 | 8560h | 7704h |  |  | Rel-6 |  |  |  |  |  |  |
| 160 | 26.1.6 | Radio subsystem link control in 45.008 | 471d | 2002-04-19 A | 2004-02-06 | 90% | 47.1d | 2002-04-19 | 2003-06-27 | 311d | 485d | finish no earlier than 2004-02-06 | G1 | 3768h | 3391.2h |  |  | Rel-6 |  |  |  |  |  |  |
| 161 | 26.1.7 | Requirements in 44.004 | 471d | 2002-04-19 A | 2004-02-06 | 90% | 47.1d | 2002-04-19 | 2003-06-27 | 311d | 485d | finish no earlier than 2004-02-06 | G2 | 3768h | 3391.2h |  |  | Rel-6 |  |  |  |  |  |  |

Notes:
- 136: A Sultan merged "Presence Service Enhancements" (UID31028, PRES1) to this feature as no answer was provided on why Presence and Presence Encmts had same target completion date
- 140: Also for 31022 IMS Messaging
- 141: LSs handled in SA3. WID approved SA#17 Contribution at S3#25 & following e-mail discussion.
- 143: Closed
- 153: Nokia, Ericsson, Siemens, Telia
- 154: Started

| ID | WBS | Task | Duration | Start | Finish | Complete | Remaining | Baseline start | Baseline finish | Baseline duration | Total slack | Constraint | Resources | Work | Actual work | Text1 | Text4 | Text5 | Text6 | Text3 | Text8 | Text7 | Text9 |
| --- | --- | --- | --- | --- | --- | --- | --- | --- | --- | --- | --- | --- | --- | --- | --- | --- | --- | --- | --- | --- | --- | --- | --- |
| 162 | 26.2 | **Signalling and protocol support for a Flexible Layer One** | 471d | 2002-04-19 A | 2004-02-06 | 80% | 94.2d | 2002-04-19 | 2003-06-27 | 311d | 485d |  | G2 | 11304h | 7027.2h | FLOGER-SigPro | Benoist Sébire | benoist.sebire@nokia.com | Rel-6 |  |  |  |  |
| 163 | 26.2.1 | Modifications to RLC/MAC in 44.060 and 44.160 | 471d | 2002-04-19 A | 2004-02-06 | 80% | 94.2d | 2002-04-19 | 2003-06-27 | 311d | 485d | finish no earlier than 2004-02-06 | G2 | 3768h | 3014.4h |  |  |  | Rel-6 |  |  |  |  |
| 164 | 26.2.2 | Modifications to RRC in 44.118 and 44.018 | 471d | 2002-04-19 A | 2004-02-06 | 80% | 94.2d | 2002-04-19 | 2003-06-27 | 311d | 485d | finish no earlier than 2004-02-06 | G2 | 3768h | 3014.4h |  |  |  | Rel-6 |  |  |  |  |
| 165 | 26.3 | **Security for a Flexible Layer One** | 356d | 2002-04-19 A | 2003-08-29 A | 100% |  | 2002-04-19 | 2003-06-27 | 311d |  |  | S3, G2 | 5663.04h | 5663.04h | FLOGER-SecFLO | Benoist Sébire | benoist.sebire@nokia.com | Rel-6 |  |  |  |  |
| 166 | 26.3.1 | Ciphering in 44.160,44.118, 44.060 and 44.018 | 356d | 2002-04-19 A | 2003-08-29 A | 100% |  | 2002-04-19 | 2003-06-27 | 311d |  | finish no earlier than 2003-08-29 | S3, G2 | 2848h | 2848h |  |  |  | Rel-6 |  |  |  |  |
| 167 | 26.4 | **GERAN MS Conformance test for the Flexible Layer One** | 101d | 2004-02-06 | 2004-06-25 |  |  | 2002-11-22 | 2003-11-21 | 260.5d | 385d |  | G4; G5 | 3232h |  | FLOGER-Msconf | Benoist Sébire | benoist.sebire@nokia.com | Rel-6 |  |  |  |  |
| 168 | 26.4.1 | MS Test in 51.01050085 | 101d | 2004-02-06 | 2004-06-25 |  |  | 2002-11-22 | 2003-11-21 | 260.5d | 385d | start no earlier than 2004-02-06 | G4; G5 | 1616h |  |  |  |  | Rel-6 |  |  |  |  |
| 169 | 26.5 | **GERAN BTS Conformance test for the Flexible Layer One** | 101d | 2004-02-06 | 2004-06-25 |  |  | 2002-04-19 | 2003-11-21 | 416d | 385d |  | G3 | 1616h |  | FLOGER-BTSconf | Benoist Sébire | benoist.sebire@nokia.com | Rel-6 |  |  |  |  |
| 170 | 26.5.1 | BTS Test in 51.021 | 101d | 2004-02-06 | 2004-06-25 |  |  | 2002-04-19 | 2003-11-21 | 416d | 385d | start no earlier than 2004-02-06 | G3 | 808h |  |  |  |  | Rel-6 |  |  |  |  |
| 171 | 27 | Uplink TDOA feasibility study | 151d | 2001-11-30 A | 2002-06-28 A | 100% |  | 2001-11-30 | 2002-06-28 | 151d |  | finish no earlier than 2002-06-28 | GP | 1208h | 1208h | TDOAF | Bob Gross, TruePosition, Inc. | rlgross@trueposition.com | Rel-6 | 45.811 | Paolo |  |  |
| 172 | 28 | **Multimedia Broadcast and Multicast Service** | 816d? | 2001-05-11 A | 2004-06-25 | 32% | 555.45d? | 2001-05-11 | 2004-03-19 | 746d | 385d |  | S1 | 97545.6h | 29027.9h | MBMS |  |  | Rel-6 |  | Michael | TSG |  |
| 173 | 28.1 | Stage 1 | 232d | 2001-05-11 A | 2002-04-01 A | 100% |  | 2001-05-11 | 2002-04-01 | 232d |  | finish no earlier than 2002-04-01 | S1 | 1856h | 1856h |  |  |  | Rel-6 | 22.146, 22.101 |  |  | 11003 |
| 174 | 28.2 | **Stage 2** | 635d | 2001-09-24 A | 2004-02-27 | 90% | 63.5d | 2001-09-24 | 2003-09-19 | 520d | 470d |  | S2 | 10200h | 5932.8h |  |  |  | Rel-6 |  |  | TSG |  |
| 175 | 28.2.1 | TR on Architectural Study | 240d | 2001-09-24 A | 2002-08-23 A | 100% |  | 2001-09-24 | 2002-08-23 | 240d |  | finish no earlier than 2002-08-23 | S2 | 1920h | 1920h |  |  |  | Rel-6 |  |  |  |  |
| 176 | 28.2.2 | Stage 2 Specification Work. (User Service aspects may impact) | 400d | 2002-08-19 A | 2004-02-27 | 84% | 64d | 2002-08-19 | 2003-09-19 | 285d | 470d | finish no earlier than 2004-02-27 | S2 | 3200h | 2688h |  |  |  | Rel-6 |  |  |  |  |
| 177 | 28.3 | Introduction of MBMS in RAN | 640d | 2002-01-01 A | 2004-06-14 | 60% | 256d | 2002-01-01 | 2004-03-19 | 579d | 394d | finish no earlier than 2004-06-14 | R2 | 5120h | 3072h | MBMS-RAN | Juho Pirskanen , Nokia | juho.pirskanen@nokia.com | Rel-6 |  | MCC_RAN | TSG | 2481 |
| 178 | 28.4 | Support of the MBMS in CN protocols | 454d | 2002-06-18 A | 2004-03-12 | 50% | 227d | 2002-06-18 | 2003-12-12 | 389d | 460d | finish no earlier than 2004-03-12 | N1 | 3632h | 1816h |  |  |  | Rel-6 |  |  | TSG |  |
| 179 | 23.5 | Gmb interface for MBMS (CN3 part) | 211d | 2003-08-29 A | 2004-06-18 | 10% | 189.9d |  |  |  | 390d | finish no earlier than 2004-06-18 | N3 | 1688h | 168.8h |  |  |  | Rel-6 |  |  |  |  |
| 180 | 28.5 | Security Aspects of Multimedia Broadcast/Multicast Service (MBMS) | 324d | 2002-07-01 A | 2003-09-25 | 20% | 259.2d | 2002-07-01 | 2003-02-28 | 175d | 581d | finish no earlier than 2003-09-25 | S3 | 2592h | 518.4h | MBMS | Escott, Adrian, 3 | adrian.escott@three.co.uk | Rel-6 |  |  | TSG |  |
| 181 | 28.6 | **Support of MBMS in GERAN** | 737d? | 2001-08-30 A | 2004-06-25 | 20% | 590.03d? | 2002-08-30 | 2003-11-21 | 321d | 385d |  | GP | 56784h | 10749.5h | MBMS-GERAN |  |  | Rel-6 |  |  | TSG |  |
| 182 | 28.6.1 | Impact on the logical and physical channels | 476d | 2002-08-30 A | 2004-06-25 | 25% | 357d | 2002-08-30 | 2003-11-21 | 321d | 385d | finish no earlier than 2004-06-25 | GP | 3808h | 952h |  |  |  | Rel-6 |  |  |  |  |
| 183 | 28.6.2 | Simultaneous support of MBMS services | 216d | 2002-08-30 | 2003-06-27 |  |  | 2002-08-30 | 2003-06-27 | 216d | 645d | finish no earlier than 2003-06-27 | G1 | 1728h |  |  |  |  | Rel-6 |  |  |  |  |
| 184 | 28.6.3 | Simultaneous support of MBMS and non-MBMS services | 216d | 2002-08-30 | 2003-06-27 |  |  | 2002-08-30 | 2003-06-27 | 216d | 645d | finish no earlier than 2003-06-27 | G1 | 1728h |  |  |  |  | Rel-6 |  |  |  |  |
| 185 | 28.6.4 | Re-synchronisation at cell change | 216d | 2002-08-30 | 2003-06-27 |  |  | 2002-08-30 | 2003-06-27 | 216d | 645d | finish no earlier than 2003-06-27 | G2 | 1728h |  |  |  |  | Rel-6 |  |  |  |  |
| 186 | 23.7.5 | Simultaneous support of MBMS services | 476d? | 2002-08-30 A | 2004-06-25 | 25% | 357d? |  |  |  | 385d | finish no earlier than 2004-06-25 | GP | 3808h | 952h |  |  |  | Rel-6 |  |  |  |  |
| 187 | 23.7.6 | Simultaneous support of MBMS and non-MBMS services | 737d? | 2001-08-30 A | 2004-06-25 | 25% | 552.75d? |  |  |  | 385d | finish no earlier than 2004-06-25 | GP | 5896h | 1474h |  |  |  | Rel-6 |  |  |  |  |
| 188 | 23.7.7 | Resynchronisation at cell change | 737d? | 2001-08-30 A | 2004-06-25 | 25% | 552.75d? |  |  |  | 385d | start no earlier than 2001-08-30 | GP | 5896h | 1474h |  |  |  | Rel-6 |  |  |  |  |
| 189 | 28.6.5 | Decision making process between point-to-point or pont-to-multipoint configurations | 476d | 2002-08-30 A | 2004-06-25 | 25% | 357d | 2002-08-30 | 2003-11-21 | 321d | 385d | finish no earlier than 2004-06-25 | GP | 3808h | 952h |  |  |  | Rel-6 |  |  |  |  |
| 190 | 28.6.6 | MBMS channel allocations procedures to multiple MSs | 476d | 2002-08-30 A | 2004-06-25 | 25% | 357d | 2002-08-30 | 2003-11-21 | 321d | 385d | finish no earlier than 2004-06-25 | GP | 3808h | 952h |  |  |  | Rel-6 |  |  |  |  |
| 191 | 28.6.7 | Changes to the Gb interface | 476d | 2002-08-30 A | 2004-06-25 | 25% | 357d | 2002-08-30 | 2003-11-21 | 321d | 385d | finish no earlier than 2004-06-25 | GP | 3808h | 952h |  |  |  | Rel-6 |  |  |  |  |
| 192 | 28.6.8 | GERAN specific changes to the Iu-ps interface | 476d | 2002-08-30 A | 2004-06-25 | 25% | 357d | 2002-08-30 | 2003-11-21 | 321d | 385d | finish no earlier than 2004-06-25 | GP | 3808h | 952h |  |  |  | Rel-6 |  |  |  |  |
| 193 | 28.6.9 | Interaction between MBMS and Iu-flex | 476d | 2002-08-30 A | 2004-06-25 | 25% | 357d | 2002-08-30 | 2003-11-21 | 321d | 385d | finish no earlier than 2004-06-25 | GP | 3808h | 952h |  |  |  | Rel-6 |  |  |  |  |
| 194 | 28.6.10 | Security aspects | 476d | 2002-08-30 A | 2004-06-25 | 25% | 357d | 2002-08-30 | 2003-11-21 | 321d | 385d | finish no earlier than 2004-06-25 | GP | 3808h | 952h |  |  |  | Rel-6 |  |  |  |  |
| 195 | 23.7.14 | MS conformance tests- G3 | 476d? | 2002-08-30 | 2004-06-25 |  |  |  |  |  | 385d | start no earlier than 2002-08-30 | G3 | 3808h |  |  |  |  | Rel-6 |  |  |  |  |
| 196 | 28.6.11 | MS conformance tests - G5 | 216d | 2002-08-30 | 2003-06-27 |  |  | 2002-08-30 | 2003-06-27 | 216d | 645d | finish no earlier than 2003-06-27 | G5 | 1728h |  |  |  |  | Rel-6 |  |  |  |  |

Notes:
- 162: Started
- 165: Started
- 167: Not started
- 169: Not started
- 172: Title renamed at SA#13
- 173: This may or may not be a separate stage 1. In the meantime, CRs are proposed for 22.101
- 180: WID approved SA#17

| ID | WBS | Task | Duration | Start | Finish | Complete | Remaining | Baseline start | Baseline finish | Baseline duration | Total slack | Constraint | Resources | Work | Actual work | Text3 | Text6 | Text8 | Text9 | Text1 | Text4 | Text5 | Text7 |
| --- | --- | --- | --- | --- | --- | --- | --- | --- | --- | --- | --- | --- | --- | --- | --- | --- | --- | --- | --- | --- | --- | --- | --- |
| 197 | 28.1 | **MBMS User Services** | 745d? | 2001-05-11 A | 2004-03-18 | 52% | 356.5d? | 2001-05-11 | 2002-04-01 | 232d | 456d |  | S1 | 9424h | 4914.41h | 22.246 | Rel-6 | Michael | 11003 |  |  |  |  |
| 198 | 28.1 | MBMS User Services Stage 1 | 232d | 2001-05-11 A | 2002-04-01 | 80% | 46.4d | 2001-05-11 | 2002-04-01 | 232d | 969d | finish no earlier than 2002-04-01 | S1 | 1856h | 1484.8h | 22.246 | Rel-6 | Michael | 11003 |  |  |  |  |
| 199 | 23.8.2 | Definition of MBMS user services, media codecs, formats and transport/application protocols using MBMS | 201d? | 2003-06-12 A | 2004-03-18 | 20% | 160.8d? | 2003-06-12 | 2004-03-18 | 201d? | 456d | finish no earlier than 2004-03-18 | S4 | 1608h | 321.6h |  | Rel-6 |  |  | MBMS-TSMBMS | Igor Curcio (Nokia) | igor.curcio@nokia.com | TSG |
| 200 | 29 | **Speech Recognition and Speech Enabled Services** | 640d? | 2001-10-08 A | 2004-03-19 | 41% | 380.35d? | 2001-10-08 | 2003-12-09 | 567d? | 455d |  | S1 | 12192h | 4946.31h |  | Rel-6 | Michael |  | SRSES |  |  | TSG |
| 201 | 29.1 | Speech Enabled Services Based on Distributed Speech Recognition (DSR) | 115d | 2001-10-08 A | 2002-03-15 A | 100% |  | 2001-10-08 | 2002-03-15 | 115d |  | finish no earlier than 2002-03-15 | S1 | 920h | 920h | 22.941, 23.207, 22.243 | Rel-6 |  |  | DSR | D Williams, QUALCOMM, Inc. | Dwilliams@qualcomm.com | TSG |
| 202 | 29.2 | TR on Architectural impacts | 212d | 2003-05-12 A | 2004-03-02 | 62% | 80.56d | 2003-05-12 | 2003-12-09 | 152d | 468d | finish no earlier than 2004-03-02 | S2 | 1696h | 1051.52h |  | Rel-6 |  |  |  |  |  |  |
| 203 | 29.3 | TO BE DELETED AT CN#23-SES codec negotiation at SDP | 183d | 2002-09-23 | 2003-06-04 |  |  | 2002-09-23 | 2003-06-04 | 183d | 662d | finish no earlier than 2003-06-04 | N1 | 1464h |  |  | Rel-6 |  |  |  |  |  |  |
| 204 | 24.4 | Codec Work to Support Speech Recognition Framework for Automated Voice Services | 374d? | 2002-10-15 A | 2004-03-19 | 30% | 261.8d? | 2002-10-15 | 2003-09-26 | 249d? | 455d | finish no earlier than 2004-03-19 | S4 | 2992h | 897.6h | 22.243 | Rel-6 |  |  | SRSES-Codec | David Pearce, Motorola | bdp003@motorola.com | WG |
| 205 | 30 | **Generic User Profile** | 705d | 2001-10-08 A | 2004-06-18 | 60% | 285.16d | 2001-10-08 | 2003-12-12 | 570d | 390d |  | S1 | 27391.8h | 16312.3h |  | Rel-6 | Michael |  | GUP |  |  | TSG |
| 206 | 30.1 | Stage 1 - Requirements | 430d | 2001-10-08 A | 2003-05-30 | 99% | 4.3d | 2001-10-08 | 2003-05-30 | 430d | 665d | finish no earlier than 2002-12-09 | S1 | 3440h | 3405.6h | 22.240, 22.228 | Rel-6 |  |  |  | Paul Amery (Orange) | paul.amery@orange.co.uk |  |
| 207 | 30.3 | Stage 2 - Architecture | 355d | 2002-01-28 A | 2003-06-06 A | 100% |  | 2002-01-28 | 2003-06-06 | 355d |  | finish no earlier than 2003-06-06 | S2 | 2840h | 2840h | 23.240 | Rel-6 |  |  |  | Nacho Uzquiano (Telefonica) | uzquiano_ji@tsm.es |  |
| 208 | 30.2 | Stage 2 - Data Description Method | 648d | 2001-10-08 A | 2004-03-31 | 60% | 259.2d | 2001-10-08 | 2003-12-10 | 568d | 447d | finish no earlier than 2003-03-12 | T2 | 5184h | 3110.4h | 23.241 | Rel-6 | Friedhelm |  |  | Kurt Bischinger (T-Mobile AUSTRIA) | kurt.bischinger@t-mobile.at | TSG |
| 209 | 30.4 | Stage 3 - Common objects | 693d | 2001-10-08 A | 2004-06-02 | 50% | 346.5d | 2001-10-08 | 2003-12-10 | 568d | 402d | finish no earlier than 2004-06-02 | T2 | 5544h | 2772h | 24.241 | Rel-6 | Friedhelm |  |  |  |  | TSG |
| 210 | 30.5 | Stage 3 - Network | 284.98d | 2003-05-19 A | 2004-06-18 | 20% | 227.98d | 2003-05-19 | 2003-12-12 | 149.98d | 390d | finish no earlier than 2004-06-18 | N4 | 2279.84h | 455.97h | 29.240 | Rel-6 |  |  |  |  |  |  |
| 211 | 30.6 | Security Aspects | 308d | 2002-07-16 A | 2003-09-18 | 15% | 261.8d | 2002-07-16 | 2003-09-18 | 308d | 586d | finish no earlier than 2003-09-18 | S3 | 2464h | 369.6h | 33.102, 33.203, 33.210 | Rel-6 |  |  |  | Owen, Bradley | bvowen@lucent.com | WG |
| 212 | 31 | **Digital Rights Management** | 380d? | 2001-10-08 A | 2003-03-21 | 49% | 194.82d? | 2001-10-08 | 2003-03-21 | 380d? | 715d |  | S1 | 7200h | 3508.61h |  | Rel-6 | Michael |  | DRM |  |  | TSG |
| 213 | 31.1 | Requirements | 179d | 2001-10-08 A | 2002-06-13 A | 100% |  | 2001-10-08 | 2002-06-13 | 179d |  | finish no earlier than 2002-06-13 | S1 | 1432h | 1432h |  | Rel-6 |  |  |  | Nicholas Wood, Openwave Systems | nicholas.wood@openwave.com |  |
| 214 | 26.2 | Monitoring of Stages 2 and 3 progress (actual work to be done by OMA) | 155d? | 2002-08-19 | 2003-03-21 |  |  | 2002-08-19 | 2003-03-21 | 155d? | 715d | start no earlier than 2002-08-19 | S1 | 1240h |  |  | Rel-6 |  |  |  |  |  |  |
| 215 | 31.3 | Monitoring of Security (work done by OMA) | 186d | 2002-06-17 A | 2003-03-03 | 40% | 111.6d | 2002-06-17 | 2003-03-03 | 186d | 729d | finish no earlier than 2003-03-03 | S3 | 1488h | 595.2h |  | Rel-6 |  |  |  |  |  |  |
| 216 | 32 | **WLAN-UMTS Interworking** | 1165d? | 2000-01-03 A | 2004-06-18 | 87% | 152.74d? | 2000-01-03 | 2003-12-12 | 1030d? | 390d |  | S1 | 33176h | 28826.5h |  | Rel-6 | Michael |  | WLAN | Fredric Paint, Telenor | frederic.paint@telenor.com | TSG |
| 217 | 32.1 | Technical Report | 900d? | 2000-01-03 A | 2003-06-13 | 99% | 9d? | 2000-01-03 | 2003-06-13 | 900d? | 655d | finish no earlier than 2003-06-13 | S1 | 7200h | 7128h | 22.934, 22.101, 22.105 | Rel-6 |  |  | WLAN-TR | Fredric Paint, Telenor | frederic.paint@telenor.com |  |
| 218 | 27.2 | CRs to implement WLAN | 900d? | 2000-01-03 A | 2003-06-13 | 99% | 9d? | 2000-01-03 | 2003-06-13 | 900d? | 655d | finish no earlier than 2003-06-13 | S1 | 7200h | 7128h | 22.934, 22.101, 22.105, 22.115 | Rel-6 |  |  | WLAN-CR | Fredric Paint, Telenor | frederic.paint@telenor.com |  |
| 219 | 32.2 | Architecture Definition | 505d | 2002-03-25 A | 2004-02-27 | 87% | 65.65d | 2002-03-25 | 2003-09-26 | 395d | 470d | finish no earlier than 2004-02-27 | S2 | 4040h | 3514.8h |  | Rel-6 |  |  |  |  |  | TSG |
| 220 | 32.3 | Security | 125d | 2002-09-30 A | 2003-03-21 | 30% | 87.5d | 2002-09-30 | 2003-03-21 | 125d | 715d | finish no earlier than 2003-03-21 | S3 | 1000h | 300h | 21.133, 33.106, 33.107, 33.108, 33.200, 33.203, 33.210 | Rel-6 |  |  |  | Lopez-Soria, Luis, Ericsson | luis.lopez-soria@ece.ericsson.se | TSG |
| 221 | 27.5 | Stage 3 - CN4 aspects | 281d? | 2003-05-23 A | 2004-06-18 | 70% | 84.3d? | 2003-05-23 | 2003-12-12 | 146d? | 390d | finish no earlier than 2004-06-18 | N4 | 2248h | 1573.6h | 29.234, 29.061 | Rel-6 |  |  | WLAN-IW | Rodriguez ,Raquel, Nokia | raquel.rodriguez@nokia.com | TSG |
| 222 | 27.6 | WLAN interworking- stage 3 | 271d? | 2003-05-23 A | 2004-06-04 | 50% | 135.5d? | 2003-05-23 | 2003-12-12 | 146d? | 400d | finish no earlier than 2004-06-04 | N1 | 2168h | 1084h |  | Rel-6 |  |  |  |  |  | WG |

Notes:
- 203: renamed according to Hannu's indication
- 210: 17 May no activity in CN4...
- 211: WID approved SA#17. SA WG3 progress slow, depends on progress in other groups.
- 212: Foreseen start and completion dates introduced by MCC (no indication at all on the WID)
- 215: SA3 acknowledge role in WI at SA3#20. Active contribution S3#24, S3#25. S3 WID approved SA#17
- 220: Active contribution S3#24, S3#25. WID approved SA#17
- 221: WID approved at CN#19......

| ID | WBS | Task | Duration | Start | Finish | Complete | Remaining | Baseline start | Baseline finish | Baseline duration | Total slack | Constraint | Resources | Work | Actual work | Text1 | Text6 | Text7 | Text8 | Text3 | Text4 | Text5 | Text9 | Text10 | Text11 | Text12 |
| --- | --- | --- | --- | --- | --- | --- | --- | --- | --- | --- | --- | --- | --- | --- | --- | --- | --- | --- | --- | --- | --- | --- | --- | --- | --- | --- |
| 223 | 33 | **Priority Service** | 347d? | 2002-05-30 A | 2003-09-26 | 67% | 116.04d? | 2002-05-30 | 2003-09-26 | 347d? | 580d |  | S1 | 7512h | 4999.9h | PRIOR | Rel-6 | TSG | Michael |  |  |  |  |  |  |  |
| 224 | 33.1 | Feasibility Study | 1d | 2002-06-14 A | 2002-06-14 A | 100% |  | 2002-06-14 | 2002-06-14 | 1d |  | finish no earlier than 2002-06-14 | S1 | 8h | 8h | PRIOR-FS | Rel-6 |  | Michael | 22.950 | Biplab K. Pramanik, Telcordia Technologies | bpramani@telcordia.com |  |  |  |  |
| 225 | 33.2 | Stage 1 - Requirements | 340d | 2002-05-30 A | 2003-09-17 | 85% | 51d | 2002-05-30 | 2003-09-17 | 340d | 587d | finish no earlier than 2003-09-17 | S1 | 2720h | 2312h | PRIOR-SR | Rel-6 |  | Michael |  | James J. Garrahan, Telcordia Technologies | bpramani@telcordia.com |  |  |  |  |
| 226 | 28.3 | Priority Multimedia Service | 131d? | 2003-03-28 | 2003-09-26 |  |  | 2003-03-28 | 2003-09-26 | 131d? | 580d | finish no earlier than 2003-09-26 | S1 | 1048h |  |  | Rel-6 |  |  |  |  |  |  |  |  |  |
| 227 | 28.4 | Priority service implementation guide | 131d? | 2003-03-28 A | 2003-09-26 | 85% | 19.65d? | 2003-03-28 | 2003-09-26 | 131d? | 580d | finish no earlier than 2003-09-26 | S1 | 1048h | 890.8h |  | Rel-6 |  |  | 22.952 | Biplab K. Pramanik, Telcordia Technologies | bpramani@telcordia.com |  |  |  |  |
| 228 | 34 | **Network Sharing** | 366d? | 2003-01-20 A | 2004-06-14 | 57% | 156.4d? | 2003-01-20 | 2003-12-19 | 240d? | 394d |  | S1 | 12608h | 7220.26h | NTShar | Rel-6 | TSG | Michael |  |  |  |  |  |  |  |
| 229 | 34.1 | Technical Report | 240d? | 2003-01-20 A | 2003-12-19 A | 100% |  | 2003-01-20 | 2003-12-19 | 240d? |  |  | S1 | 1920h | 1920h | NTShar-TR | Rel-6 |  | Michael | 22.951 |  |  |  |  |  |  |
| 230 | 29.2 | Stage 1 - CRs to implement Network Sharing | 240d? | 2003-01-20 A | 2003-12-19 A | 100% |  | 2003-01-20 | 2003-12-19 | 240d? |  | finish no earlier than 2003-12-19 | S1 | 1920h | 1920h | NTShar-CR | Rel-6 |  |  | 22.011, 22.101, 22.115, 22.129 |  |  |  |  |  |  |
| 231 | 29.3 | Stage 2 | 269d? | 2003-02-27 A | 2004-03-09 | 74% | 69.94d? | 2003-02-27 | 2003-12-19 | 212d? | 463d | finish no earlier than 2004-03-09 | S2 | 2152h | 1592.48h |  | Rel-6 |  |  |  |  |  |  |  |  |  |
| 232 | 29.4 | Network sharing - stage 3 | 271d? | 2003-05-23 A | 2004-06-04 | 2% | 265.58d? | 2003-05-23 | 2003-12-12 | 146d? | 400d | finish no earlier than 2004-06-04 | N1 | 2168h | 43.36h |  | Rel-6 | WG |  |  |  |  |  |  |  |  |
| 233 | 29.5 | Enhancement of the support of network sharing in the UTRAN | 192d | 2003-09-19 A | 2004-06-14 | 5% | 182.4d |  |  |  | 394d | start no earlier than 2003-09-19 | R2 | 1536h | 76.8h | NTShar-UTRANEnh | Rel-6 | TSG | MCC_RAN | TS25.401, TS25.413, TS25.331, TS25.304 | Anders Dahlén, TeliaSonera | Anders.Dahlen@TeliaSonera.com | BB | 31018 | Active | 48 |
| 234 | 35 | **QoS Improvements** | 448d? | 2002-07-15 A | 2004-03-31 | 60% | 178.37d? | 2000-01-03 | 2003-12-19 | 1035d? | 447d |  | S2 | 9784h | 5888.45h | QoS1 | Rel-6 | TSG | Sang-Ui |  |  |  |  |  |  |  |
| 235 | 35.1 | FS on Dynamic Policy control enhancements for end-to-end QoS | 432d | 2002-07-15 A | 2004-03-09 | 79% | 90.72d | 2002-07-15 | 2003-12-19 | 375d | 463d | finish no earlier than 2004-03-09 | S2 | 3456h | 2730.24h | QoS1 | Rel-6 | TSG |  |  |  | Claire Mousset, Nortel |  |  |  |  |
| 236 | 30.2 | Definition of the Gq interface | 197d? | 2003-07-01 A | 2004-03-31 | 45% | 108.35d? | 2000-01-03 | 2000-01-03 | 1d? | 447d | finish no earlier than 2004-03-31 | S2 | 1576h | 709.2h |  | Rel-6 |  |  |  | Janne Rinne (Nokia) |  |  |  |  |  |
| 237 | 30.3 | Gq interface specification for Dynamic Policy control enhancements – Stage 3 | 146d | 2003-08-29 A | 2004-03-19 | 25% | 109.5d |  |  |  | 455d | finish no earlier than 2004-03-19 | N3 | 1168h | 292h |  | Rel-6 | TSG |  | 24,228, 29.207, 29.208 | Anna Sillanpää, Nokia | Anna.Sillanpaai@nokia.com |  |  |  |  |
| 238 | 36 | **Support for subscriber certificates** | 613d? | 2002-02-25 A | 2004-06-30 | 47% | 327.26d? | 2002-02-25 | 2002-11-14 | 189d | 382d |  | S3 | 7880h | 3673.1h | SEC1-SC | Rel-6 | TSG | Maurice | 33.102 | Valtteri Niemi, Nokia | valtteri.niemi@nokia.com |  |  |  |  |
| 239 | 36.1 | Stage 1 | 144d | 2002-02-25 A | 2002-09-12 | 40% | 86.4d | 2002-02-25 | 2002-09-12 | 144d | 851d | finish no earlier than 2002-09-12 | S3 | 1152h | 460.8h |  | Rel-6 |  |  |  |  |  |  |  |  |  |
| 240 | 36.2 | Architecture review | 24d | 2002-10-14 A | 2002-11-14 A | 100% |  | 2002-10-14 | 2002-11-14 | 24d |  | finish no earlier than 2002-11-14 | S2 | 192h | 192h |  | Rel-6 |  |  |  |  |  |  |  |  |  |
| 241 | 31.3 | Stage 3 | 204d? | 2003-09-19 A | 2004-06-30 | 45% | 112.2d? |  |  |  | 382d | finish no earlier than 2004-06-30 | N4 | 1632h | 734.4h | SEC1-SC | Rel-6 |  | Kimmo |  | Lauri Laitinen, Nokia |  |  |  |  |  |
| 242 | 32 | **Rel-6 OSA enhancements** | 427d? | 2002-10-31 A | 2004-06-18 | 69% | 133.76d? | 2002-02-14 | 2003-12-19 | 481.85d? | 390d |  | S1 | 21575.2h | 13822.7h | OSA3 | Rel-6 | TSG | Adrian | 22.127, 29.198, 29.998 | Chelo ABARCA (Alcatel) | Chelo.Abarca@alcatel.fr |  |  |  |  |
| 243 | 32.1 | Scope of the Open Service Access Release 6 | 66d? | 2003-03-28 A | 2003-06-27 | 90% | 6.6d? | 2003-03-28 | 2003-06-27 | 66d? | 645d | finish no earlier than 2003-06-27 | S1 | 528h | 475.2h |  | Rel-6 | TSG |  |  |  |  |  |  |  |  |
| 244 | 32.2 | Multi Media Messaging function | 427d? | 2002-10-31 A | 2004-06-18 | 50% | 213.5d? | 2002-10-31 | 2003-12-19 | 297d? | 390d | finish no earlier than 2004-06-18 | N5 | 3416h | 1708h |  | Rel-6 | TSG |  | 29.198, 29.998 |  |  |  |  |  |  |
| 245 | 32.3 | Policy management extensions | 292d? | 2002-10-31 A | 2003-12-12 | 90% | 29.2d? | 2002-10-31 | 2003-12-19 | 297d? | 525d | finish no earlier than 2003-12-12 | N5 | 2336h | 2102.4h |  | Rel-6 | TSG |  | 29.198, 29.998 |  |  |  |  |  |  |
| 246 | 32.4 | Presence and Availability Management (from the PRESNC WI) | 367d? | 2002-10-31 A | 2004-03-26 | 80% | 73.4d? | 2002-10-31 | 2003-12-19 | 297d? | 450d | finish no earlier than 2004-03-26 | N5 | 2936h | 2348.8h |  | Rel-6 | TSG |  | 29.198, 29.998 |  |  |  |  |  |  |
| 247 | 32.5 | OSA interfaces at different levels of abstractions (Parlay X, Web services) | 245d? | 2003-07-14 A | 2004-06-18 | 90% | 24.5d? | 2003-03-14 | 2003-12-19 | 201d? | 390d | finish no earlier than 2004-02-27 | N5 | 1960h | 1764h |  | Rel-6 | TSG |  | 29.199 |  |  |  |  |  |  |
| 248 | 32.6 | Introduction of migration support mechanism | 291d? | 2002-11-01 A | 2003-12-12 A | 100% |  | 2003-03-14 | 2003-12-19 | 201d? |  | finish no earlier than 2003-12-12 | N5 | 2328h | 2328h |  | Rel-6 | TSG |  | 29.198, 29.998 |  |  |  |  |  |  |
| 249 | 32.7 | User Profile | 367d? | 2002-10-31 | 2004-03-26 |  |  | 2003-03-14 | 2003-12-19 | 201d? | 450d | start no earlier than 2002-10-31 | N5 | 2936h |  |  | Rel-6 | TSG |  | 29.198, 29.998 |  |  |  |  |  |  |
| 250 | 32.8 | Framework Function for Federation | 225d? | 2003-02-03 A | 2003-12-12 A | 100% |  | 2003-03-14 | 2003-12-19 | 201d? |  | finish no earlier than 2003-12-12 | N5 | 1800h | 1800h |  | Rel-6 | TSG |  | 29.198, 29.998 |  |  |  |  |  |  |

Notes:
- 238: Approved at SA#14. This may require BBs from CN1, CN4, SA5 and T3
- 239: Contribution received S3#24, S3#25
- 241: WID approved at CN#21......
- 242: NP-030036 Rev WID replaces SP-020573.
- 244: N5#25: No progress reflected in the specs.
- 245: N5#25: Good progress 40%->90%
- 246: N5#25: Completion 09/04; consistent with CN1 delayed Rel-6 completion.TS completion in 12/2003 & TR completion in 09/2004.Good progress 40%->80%
- 247: N5#25: CHANGED Start Date to the handover from Parlay (07/2003). Draft TS 29.199 v100 submitted to CN#22 for Information. Will be submitted for CN#24 approval in 06/2004.
- 248: N5#25: completed
- 249: N5#24&25: Still Pending input from SA1/2.
- 250: N5#25: completed

| ID | WBS | Task | Duration | Start | Finish | Complete | Remaining | Baseline start | Baseline finish | Baseline duration | Total slack | Constraint | Resources | Work | Actual work | Text1 | Text4 | Text6 | Text7 | Text8 | Text3 | Text5 | Text2 |
| --- | --- | --- | --- | --- | --- | --- | --- | --- | --- | --- | --- | --- | --- | --- | --- | --- | --- | --- | --- | --- | --- | --- | --- |
| 251 | 39 | **Addition of frequency bands to GSM** | 421d | 2002-06-28 A | 2004-02-06 | 6% | 396.51d | 2002-06-28 | 2003-08-29 | 306d | 485d |  | GP | 10520h | 611.9h | TAPS | Torben Themsen | Rel-6 | TSG | Paolo |  |  |  |
| 252 | 39.1 | **Addition of frequency bands to GSM – Changes to core specs** | 26d | 2002-11-15 A | 2002-12-20 A | 100% |  | 2002-11-15 | 2002-12-20 | 26d |  |  | G1 | 416h | 416h | TAPS-Specs | Torben Themsen | Rel-6 | TSG |  |  |  |  |
| 253 | 39.1.1 | Changes to core specs | 26d | 2002-11-15 A | 2002-12-20 A | 100% |  | 2002-11-15 | 2002-12-20 | 26d |  | finish no earlier than 2002-12-20 | G1 | 208h | 208h |  |  | Rel-6 |  |  |  |  |  |
| 254 | 39.2 | **Addition of frequency bands to GSM – Changes for conformance tests** | 421d | 2002-06-28 | 2004-02-06 |  |  | 2002-06-28 | 2003-08-29 | 306d | 485d |  | G4 | 6736h |  | TAPS-Conf | Torben Themsen | Rel-6 |  |  |  |  |  |
| 255 | 39.2.1 | 51.010-1 Add testing | 421d | 2002-06-28 | 2004-02-06 |  |  | 2002-06-28 | 2003-08-29 | 306d | 485d | finish no earlier than 2004-02-06 | G4 | 3368h |  |  |  | Rel-6 |  |  |  |  |  |
| 256 | 40 | **Seamless support of streaming services in A/Gb mode** | 1065d? | 2000-01-03 A | 2004-01-30 | 94% | 68.97d? | 2000-01-03 | 2003-12-19 | 1035d? | 490d |  | GP | 41088h | 37411.7h | SSStrea | José Luis Carrizo Martínez, Vodafone | Rel-6 | TSG | Paolo |  |  |  |
| 257 | 40.1 | **Identification of requirements for streaming** | 46d? | 2003-06-27 A | 2003-08-29 A | 100% |  | 2003-06-27 | 2003-06-27 | 1d? |  |  | G1 | 736h | 736h |  |  | Rel-6 |  |  |  |  |  |
| 258 | 34.1.1 | Requirements | 46d? | 2003-06-27 A | 2003-08-29 A | 100% |  | 2003-06-27 | 2003-06-27 | 1d? |  | finish no earlier than 2003-08-29 | G1 | 368h | 368h |  |  | Rel-6 |  |  |  |  |  |
| 259 | 40.2 | **Performance study of cell change mechanisms** | 955d? | 2000-01-03 A | 2003-08-29 A | 100% |  | 2000-01-03 | 2003-06-27 | 910d? |  |  | G1 | 30560h | 30560h |  |  | Rel-6 |  |  |  |  |  |
| 260 | 34.2.1 | Performance of NACC | 955d? | 2000-01-03 A | 2003-08-29 A | 100% |  | 2000-01-03 | 2003-06-27 | 910d? |  | finish no earlier than 2003-08-29 | G1 | 7640h | 7640h |  |  | Rel-6 |  |  |  |  |  |
| 261 | 34.2.2 | Performance of cell change in DTM for the PS domain | 955d? | 2000-01-03 A | 2003-08-29 A | 100% |  | 2000-01-03 | 2003-06-27 | 910d? |  | finish no earlier than 2003-08-29 | G1 | 7640h | 7640h |  |  | Rel-6 |  |  |  |  |  |
| 262 | 34.2.3 | Handover | 955d? | 2000-01-03 A | 2003-08-29 A | 100% |  | 2000-01-03 | 2003-06-27 | 910d? |  | finish no earlier than 2003-08-29 | G1 | 7640h | 7640h |  |  | Rel-6 |  |  |  |  |  |
| 263 | 40.3 | **Reduction of service interruption times and packet loss during mobility procedures** | 106d? | 2003-06-27 A | 2003-11-21 | 99% | 0d? | 2003-06-27 | 2003-06-27 | 1d? | 0d |  | G2 | 4240h | 3396h |  |  | Rel-6 |  |  |  |  |  |
| 264 | 34.3.1 | Optimisations of existing mechanisms/procedures | 106d? | 2003-06-27 A | 2003-11-21 A | 100% |  | 2003-06-27 | 2003-06-27 | 1d? |  | finish no earlier than 2003-11-21 | G2 | 848h | 848h |  |  | Rel-6 |  |  |  |  |  |
| 265 | 34.3.2 | Inter-system NACC | 106d? | 2003-06-27 A | 2003-11-21 A | 100% |  | 2003-06-27 | 2003-06-27 | 1d? |  | finish no earlier than 2003-11-21 | G2 | 848h | 848h |  |  | Rel-6 |  |  |  |  |  |
| 266 | 34.3.3 | PS Handover (within GERAN and between GERAN and UTRAN) | 106d? | 2003-06-27 A | 2003-11-21 A | 100% |  | 2003-06-27 | 2003-06-27 | 1d? |  | finish no earlier than 2003-11-21 | G2 | 848h | 848h |  |  | Rel-6 |  |  |  |  |  |
| 267 | 34.3.4 | Dependency to other features | 106d? | 2003-06-27 A | 2003-11-21 A | 100% |  | 2003-06-27 | 2003-06-27 | 1d? |  | finish no earlier than 2003-11-21 | G2 | 848h | 848h |  |  | Rel-6 |  |  |  |  |  |
| 268 | 40.5 | **MS conformance testing** | 31d? | 2003-12-19 A | 2004-01-30 | 99% | 0d? | 2003-12-19 | 2003-12-19 | 1d? | 0d |  | G4,G5 | 496h | 248h |  |  | Rel-6 |  |  |  |  |  |
| 269 | 34.4.1 | MS conformance tests | 31d? | 2003-12-19 A | 2004-01-30 A | 100% |  | 2003-12-19 | 2003-12-19 | 1d? |  | finish no earlier than 2004-01-30 | G4,G5 | 248h | 248h |  |  | Rel-6 |  |  |  |  |  |
| 270 | 34.5 | GERAN A/Gb mode security enhancements | 261d? | 2002-09-26 A | 2003-09-25 | 10% | 234.9d? | 2002-09-26 | 2003-09-25 | 261d? | 581d | finish no earlier than 2003-09-25 | S3 | 2088h | 208.8h |  | Peter Howard, Vodafone | Rel-6 |  |  | 33.102 | peter.howard@vodafone.com |  |
| 271 | 41 | Performance characterisation of default codecs for PS conversational multimedia application | 396d | 2002-09-13 A | 2004-03-19 | 60% | 158.4d | 2002-09-13 | 2003-09-26 | 271d | 455d | finish no earlier than 2004-03-19 | S4 | 3168h | 1900.8h | CODCAR | Pasi Ojala (Nokia) | Rel-6 | TSG | Paolo | TR 26.9yz | pasi.s.ojala@nokia.com |  |
| 272 | 43 | Study on Privacy Capability | 82d | 2002-11-08 A | 2003-03-03 | 60% | 32.8d | 2002-11-08 | 2003-03-03 | 82d | 729d | start no earlier than 2002-11-08 | S1 | 656h | 393.6h | PrivCap | Liz Daniel, Lucent | Rel-6 | TSG | Michael | TR 22.949 |  |  |
| 273 | 44 | **OAM&P** | 462d? | 2002-09-12 A | 2004-06-18 | 62% | 173.7d? | 2002-05-21 | 2004-03-18 | 477.3d? | 390d |  | S5 | 17317.6h | 9848.78h | OAM | Michael TRUSS (Motorola) | Rel-6 | TSG | Adrian | 32-series | Michael.Truss@MOTOROLA.COM |  |
| 274 | 44.1 | Principles, high level Requirements and Architecture | 396d | 2002-09-12 A | 2004-03-18 | 70% | 118.8d | 2002-09-12 | 2004-03-18 | 396d | 456d | finish no earlier than 2004-03-18 | S5 | 3168h | 2217.6h | OAM-AR | Michael TRUSS (Motorola) | Rel-6 | TSG |  | 32.101, 32.102 | Michael.Truss@MOTOROLA.COM | BCaM |
| 275 | 44.2 | Performance Management | 396d | 2002-09-12 A | 2004-03-18 | 70% | 118.8d | 2002-09-12 | 2004-03-18 | 396d | 456d | finish no earlier than 2004-03-18 | S5 | 3168h | 2217.6h | OAM-PM | Christian TOCHE (Nortel Networks) | Rel-6 | TSG |  | 32.41x, 52.402 | toche@NORTELNETWORKS.COM | BCaM |
| 276 | 44.4 | Network Infrastructure Management | 396d | 2002-09-12 A | 2004-03-18 | 60% | 158.4d | 2002-09-12 | 2004-03-18 | 396d | 456d | finish no earlier than 2004-03-18 | S5 | 3168h | 1900.8h | OAM-NIM | Thomas TOVINGER (Ericsson) | Rel-6 | TSG |  | 32.15x, 32.3/6/7xy | Thomas.Tovinger@emw.ericsson.se |  |

Notes:
- 252: Ready
- 254: Not started
- 257: Started
- 259: Started
- 263: Completed at GERAN#17
- 268: Closed, no work needed
- 269: Closed, no work needed
- 270: Possible changes to 33.102 or new specification needed.

| ID | WBS | Task | Duration | Start | Finish | Complete | Remaining | Baseline start | Baseline finish | Baseline duration | Total slack | Constraint | Resources | Work | Actual work | Text1 | Text3 | Text4 | Text5 | Text6 | Text7 | Text8 | Text2 | Text9 |
| --- | --- | --- | --- | --- | --- | --- | --- | --- | --- | --- | --- | --- | --- | --- | --- | --- | --- | --- | --- | --- | --- | --- | --- | --- |
| 277 | 44.5 | **Trace Management** | 456d? | 2002-09-20 A | 2004-06-18 | 43% | 260.66d? | 2003-06-06 | 2003-09-19 | 76d | 390d |  | S5 | 4240h | 1282.8h | OAM-Trace | 32.42x, 52.008 | Kari RÖNKÄ (Nokia) | kari.t.ronka@nokia.com | Rel-6 | TSG |  |  |  |
| 278 | 37.4.1 | Subscriber and equipment trace in UTRAN | 201d? | 2003-06-06 A | 2004-03-12 | 35% | 130.65d? | 2003-06-06 | 2003-09-19 | 76d? | 460d | finish no earlier than 2004-03-12 | R3 | 1608h | 562.8h | OAM-Trace-RAN |  | Yann Sehedi, Nortel | sehedic@nortelnetworks.com | Rel-6 | TSG | MCC_RAN |  |  |
| 279 | 37.4.2 | Subscriber and UE trace management | 58d | 2002-09-20 A | 2004-06-18 | 70% | 17.4d |  |  |  | 390d | finish no earlier than 2004-06-18 | S5 | 464h | 324.8h | OAM-Trace | 32.42x, 52.008 | Kari RÖNKÄ (Nokia) | kari.t.ronka@nokia.com | Rel-6 | TSG |  |  |  |
| 280 | 38 | **Charging Management** | 347d? | 2002-11-21 A | 2004-03-19 | 71% | 99.95d? | 2002-11-21 | 2004-03-18 | 346d? | 455d |  | S5 | 11712h | 7975.35h | CH | 32.2xy | Karl-Heinz NENNER (T-Mobile) | karl-heinz.nenner@t-mobile.de | Rel-6 | TSG | Adrian |  |  |
| 281 | 38.1 | Charging Management for Bearer level | 261d? | 2003-03-21 A | 2004-03-19 | 70% | 78.3d? | 2002-11-22 | 2004-03-18 | 345d? | 455d | finish no earlier than 2004-03-19 | S5 | 2088h | 1461.6h | CH-BC |  | Benni ALEXANDER (Nokia) |  | Rel-6 | TSG |  |  |  |
| 282 | 38.2 | Charging Management for the IMS | 261d? | 2003-03-21 A | 2004-03-19 | 70% | 78.3d? | 2002-11-22 | 2004-03-18 | 345d? | 455d | finish no earlier than 2004-03-19 | S5 | 2088h | 1461.6h | CH-IC |  | Ariel SHARON (Lucent) |  | Rel-6 | TSG |  |  |  |
| 283 | 38.3 | Charging Management for the Service domain | 261d? | 2003-03-21 A | 2004-03-19 | 70% | 78.3d? | 2002-11-22 | 2004-03-18 | 345d? | 455d | finish no earlier than 2004-03-19 | S5 | 2088h | 1461.6h | CH-SC |  | Gerald GÖRMER (Siemens) |  | Rel-6 | TSG |  |  |  |
| 284 | 38.4 | Overall architectural aspects of IP flow based bearer level charging | 334d? | 2002-11-21 A | 2004-03-02 | 74% | 86.84d? | 2002-11-21 | 2003-09-26 | 222d? | 468d | finish no earlier than 2004-03-02 | S2 | 2672h | 1977.28h |  |  |  |  | Rel-6 |  |  |  |  |
| 285 | 13 | **Rel-6 UICC/USIM enhancements and interworking** | 889d | 2000-09-25 A | 2004-02-19 | 99% | 8.4d | 2000-09-25 | 2003-09-17 | 778d | 476d |  | T3 | 26760h | 23288.6h | USAT1 |  |  |  | Rel-6 | TSG | Claus | Ter | 1800 |
| 286 | 13.1 | **UICC API** | 502d | 2002-03-20 A | 2004-02-19 | 98% | 10.73d | 2002-03-20 | 2003-09-17 | 391d | 476d |  | T3 | 8584h | 8400.59h | USAT1-API |  |  |  | Rel-6 |  |  | Ter | 1802 |
| 287 | 13.1.1 | Java API Test specification | 59d | 2002-03-20 A | 2002-06-10 A | 100% |  | 2002-03-20 | 2002-09-20 | 133d |  | finish no earlier than 2002-09-20 | T3 | 472h | 472h |  |  | Mario Pérez (Microelectrónica Española) |  | Rel-6 |  |  |  |  |
| 288 | 13.1.2 | Java API Test specification (TS 43.019 Rel-5) | 268d | 2002-05-30 A | 2003-06-09 A | 100% |  | 2002-05-30 | 2003-09-17 | 340d |  | finish no earlier than 2003-09-17 | T3 | 2144h | 2144h |  |  | Mario Pérez (Microelectrónica Española) |  | Rel-6 |  |  |  |  |
| 289 | 39.1.3 | 2G/3G Java Card™ API based applet interworking | 244d | 2003-03-17 A | 2004-02-19 | 95% | 12.2d |  |  |  | 476d | finish no earlier than 2004-02-19 | T3 | 1952h | 1854.4h | USAT1-API |  | Stéphane Andrau-Oberthur Card Systems |  | Rel-6 | TSG | Claus |  |  |
| 290 | 39.2 | **Rel-6 USIM toolkit enhancements** | 525d | 2000-09-25 A | 2002-09-27 | 99% | 0d | 2000-09-25 | 2002-09-27 | 525d | 0d |  | T3 | 14160h | 10910h |  |  |  |  | Rel-6 |  | Claus |  |  |
| 291 | 39.2.1 | **C SIM API** | 525d | 2000-09-25 A | 2002-09-27 A | 100% |  | 2000-09-25 | 2002-09-27 | 525d |  |  | T3 | 9960h | 9960h | USAT1-API-MULTOS |  |  |  | Rel-6 | TSG |  | Ter | 2031 |
| 292 | 39.2.1.1 | Specification | 525d | 2000-09-25 A | 2002-09-27 A | 100% |  | 2000-09-25 | 2002-09-27 | 525d |  | finish no earlier than 2002-09-27 | T3 | 4200h | 4200h |  |  | Neil Livingston – Aspects Software |  | Rel-6 | TSG |  | Ter | 2032 |
| 293 | 39.2.1.2 | Test specification | 195d | 2001-01-01 A | 2001-09-28 A | 100% |  | 2001-01-01 | 2001-09-28 | 195d |  | finish no earlier than 2001-09-28 | T3 | 1560h | 1560h |  |  | Neil Livingston – Aspects Software |  | Rel-6 | TSG |  | Ter | 2033 |
| 294 | 40 | **Packet Switched Streaming Services Rel-6** | 349d? | 2002-11-18 A | 2004-03-18 | 52% | 166.11d? | 2002-11-18 | 2003-12-19 | 285d? | 456d |  | S4 | 6120h | 3207.11h | PSSrel6 |  | Olle Franceschi (Ericsson) | Olle.Franceschi@emp.ericsson.se | Rel-6 | TSG | Paolo |  |  |
| 295 | 40.1 | Stage 1 | 86d? | 2002-11-18 A | 2003-03-17 A | 100% |  | 2002-11-18 | 2003-03-17 | 86d? |  | finish no earlier than 2003-03-17 | S1 | 688h | 688h |  | 22.233 |  |  | Rel-6 | TSG |  |  |  |
| 296 | 40.2 | Stage 3 | 330d? | 2002-12-13 A | 2004-03-18 | 40% | 198d? | 2002-12-13 | 2003-12-19 | 266d? | 456d | finish no earlier than 2004-03-18 | S4 | 2640h | 1056h | PSSrel6 | 26.233, 26.234, 26.244, 26.245, 26.246 | Olle Franceschi (Ericsson) | Olle.Franceschi@emp.ericsson.se | Rel-6 | WG | Paolo |  |  |
| 297 | 41 | AMR-WB extension for high audio quality | 330d | 2002-12-13 A | 2004-03-18 | 45% | 181.5d | 2002-12-13 | 2003-09-26 | 206d | 456d | finish no earlier than 2004-03-18 | S4 | 2640h | 1188h | AMRWB+ |  | Janne Vainio (Nokia) | janne.m.vainio@nokia.com | Rel-6 | TSG | Paolo |  |  |
| 298 | 42 | Single Antenna Receiver Interference Cancellation (SAIC) | 275.92d? | 2002-11-15 A | 2004-02-06 | 80% | 55.18d? | 2002-11-15 | 2003-11-21 | 220.92d? | 485d | finish no earlier than 2004-02-06 | GP; G1 | 4414.72h | 3531.77h | SAIC |  | Marc Grant, Cingular Wireless |  | Rel-6 | TSG |  |  |  |
| 299 | 43 | **Support of Conversational Services in A/Gb mode via the PS domain** | 406d? | 2003-02-07 A | 2004-08-27 | 23% | 310.67d? | 2003-02-07 | 2004-04-23 | 316d? | 340d |  | GP | 12792h | 1740.53h | SCSAGB |  | David Bladsjö, Ericsson | david.bladsjo@ericsson.com | Rel-6 | TSG |  |  |  |
| 300 | 43.1 | Creation of a TR | 206d? | 2003-02-07 A | 2003-11-21 A | 100% |  | 2003-02-07 | 2003-11-21 | 206d? |  | finish no earlier than 2003-11-21 | GP | 1648h | 1648h | SCSAGB-TR |  | David Bladsjö, Ericsson |  | Rel-6 | TSG |  |  |  |
| 301 | 43.2 | Stage 2 | 111d? | 2003-11-21 A | 2004-04-23 | 5% | 105.45d? | 2003-11-21 | 2004-04-23 | 111d? | 430d | finish no earlier than 2004-04-23 | GP | 888h | 44.4h | SCSAGB-Stage2 |  | David Bladsjö, Ericsson |  | Rel-6 | TSG |  |  |  |
| 302 | 43.3 | Radio Channel Support | 146d? | 2004-02-06 | 2004-08-27 |  |  | 2004-02-06 | 2004-04-23 | 56d? | 340d | finish no earlier than 2004-08-27 | GP | 1168h |  | SCSAGB-RCS |  | David Bladsjö, Ericsson |  | Rel-6 | TSG |  |  |  |
| 303 | 43.4 | Definition of radio resource management functionality | 146d? | 2004-02-06 | 2004-08-27 |  |  | 2004-02-06 | 2004-04-23 | 56d? | 340d | finish no earlier than 2004-08-27 | GP; G2 | 2336h |  | SCSAGB-RRM |  | David Bladsjö, Ericsson |  | Rel-6 | TSG |  |  |  |
| 304 | 43.5 | PS Handover | 146d? | 2004-02-06 | 2004-08-27 |  |  | 2004-02-06 | 2004-04-23 | 56d? | 340d | finish no earlier than 2004-08-27 | GP | 1168h |  | SCSAGB-PSH |  | David Bladsjö, Ericsson |  | Rel-6 | TSG |  |  |  |
| 305 | 43.6 | Modifications to FLO | 146d? | 2004-02-06 | 2004-08-27 |  |  | 2004-02-06 | 2004-04-23 | 56d? | 340d | finish no earlier than 2004-08-27 | GP; G2 | 2336h |  | SCSAGB-FLO |  | David Bladsjö, Ericsson |  | Rel-6 | TSG |  |  |  |

Notes:
- 286: 8/3/2001: test spec is based on R99 core spec, so deleted from Workplan
- 295: 2nd resp SA4
- 301: Started
- 302: Not started
- 303: Not started
- 304: Not started
- 305: Not started

| ID | WBS | Task | Duration | Start | Finish | Complete | Remaining | Baseline start | Baseline finish | Baseline duration | Total slack | Constraint | Resources | Work | Actual work | Text1 | Text4 | Text6 | Text7 | Text8 | Text3 | Text5 |
| --- | --- | --- | --- | --- | --- | --- | --- | --- | --- | --- | --- | --- | --- | --- | --- | --- | --- | --- | --- | --- | --- | --- |
| 306 | 44 | **Enhancement of dialled service for CAMEL** | 199d | 2003-03-28 A | 2003-12-31 | 57% | 85.6d | 2003-03-28 | 2003-09-19 | 126d? | 512d |  | S1 | 3184h | 1814.4h | EDCAMEL | Craig Bishop, Samsung Electronics Research Institute | Rel-6 | TSG | Andrijana |  |  |
| 307 | 44.1 | Stages 2 and 3 | 199d | 2003-03-28 A | 2003-12-31 | 57% | 85.6d | 2003-03-28 | 2003-09-19 | 126d | 512d | finish no earlier than 2003-09-19 | N2 | 1592h | 907.2h |  |  | Rel-6 |  |  |  |  |
| 308 | 45 | Bandwidth and resource savings in CS networks | 268d? | 2003-06-01 A | 2004-06-30 | 35% | 174.2d? | 2003-06-23 | 2003-11-25 | 112d? | 382d | finish no earlier than 2004-06-30 | S2 | 2144h | 750.4h | CSSAVE |  | Rel-6 |  |  | TR 23.977 |  |
| 309 | 46 | FS on (U)SIM Security Reuse by Peripheral Devices on Local Interfaces | 127d? | 2003-07-03 A | 2003-12-26 | 5% | 120.65d? | 2003-07-03 | 2003-12-26 | 127d? | 515d | finish no earlier than 2003-12-26 | S3 | 1016h | 50.8h |  | Raziq Yaqub, Toshiba America Research Inc. | Rel-6 | TSG | Maurice |  | ryaqub@tari.toshiba.com |
| 310 | 47 | **Multiple TBF in A/Gb mode** | 476d? | 2002-04-05 A | 2004-01-30 | 70% | 143.95d? | 2002-04-05 | 2004-01-30 | 476d? | 490d |  | GP; G2 | 34848h | 27408.6h | MULTBF | Gunnar Mildh, Ericsson | Rel-6 | TSG | Paolo |  |  |
| 311 | 47.1 | **Multiple TBF in A/Gb mode** | 366d? | 2002-04-05 A | 2003-08-29 A | 100% |  | 2002-04-05 | 2003-08-29 | 366d? |  |  | GP; G2 | 23424h | 23424h | MULTBF-Agbmode | Gunnar Mildh, Ericsson | Rel-6 | TSG |  |  |  |
| 312 | 47.1.1 | Multiple TBF Concept paper | 366d? | 2002-04-05 A | 2003-08-29 A | 100% |  | 2002-04-05 | 2003-08-29 | 366d? |  | finish no earlier than 2003-08-29 | GP; G2 | 5856h | 5856h |  |  | Rel-6 |  |  |  |  |
| 313 | 47.1.2 | Multiple TBF Stage 2 (43.064) CRs | 366d? | 2002-04-05 A | 2003-08-29 A | 100% |  | 2002-04-05 | 2003-08-29 | 366d? |  | finish no earlier than 2003-08-29 | GP; G2 | 5856h | 5856h |  |  | Rel-6 |  |  |  |  |
| 314 | 47.1.3 | Multiple TBF Stage 3 (44.060) CRs | 366d? | 2002-04-05 A | 2003-08-29 A | 100% |  | 2002-04-05 | 2003-08-29 | 366d? |  | finish no earlier than 2003-08-29 | GP; G2 | 5856h | 5856h |  |  | Rel-6 |  |  |  |  |
| 315 | 47.2 | Multiple TBF in A/Gb mode – MS testing | 476d? | 2002-04-05 | 2004-01-30 |  |  | 2002-04-05 | 2004-01-30 | 476d? | 490d | finish no earlier than 2004-01-30 | G3 | 3808h |  | MULTBF-Testing | Gunnar Mildh, Ericsson | Rel-6 | TSG | Paolo |  |  |
| 316 | 48 | **Alignment between the test-regimes for GERAN capable MS** | 171d? | 2003-08-29 A | 2004-04-23 | 80% | 34.2d? |  |  |  | 430d |  | G3 | 2736h | 1094.4h | ALTERE | Toubassi, Ericsson | Rel-6 | TSG | Michael |  |  |
| 317 | 48.1 | Determine the controversial test cases in the different test regimes and align them with 3GPP GERAN test specifications. Such test cases to be added to TS 51.010. | 171d? | 2003-08-29 A | 2004-04-23 | 80% | 34.2d? |  |  |  | 430d | finish no earlier than 2004-04-23 | G3 | 1368h | 1094.4h | ALTERE-TC |  | Rel-6 | TSG |  |  |  |
| 318 | 49 | Addition of U-TDOA in the CS domain | 56d? | 2003-11-21 A | 2004-02-06 | 90% | 5.6d? |  |  |  | 485d |  | GP | 448h | 403.2h | UTDOACS | Bob Gross, Rhys Robinson, TruePosition, Inc. | Rel-6 | TSG | Paolo |  | rlgross@trueposition.com |
| 319 | 50 | Addition of U-TDOA in the PS domain | 56d? | 2003-11-21 A | 2004-02-06 | 5% | 53.2d? |  |  |  | 485d | start no earlier than 2003-11-21 | GP | 448h | 22.4h | UTDOAPS | Bob Gross, Rhys Robinson, TruePosition, Inc. | Rel-6 | TSG | Paolo |  | rlgross@trueposition.com |
| 320 | 51 | **Advanced Receiver Performance** | 256d? | 2003-11-21 A | 2004-11-12 | 2% | 251.83d? |  |  |  | 285d |  | GP | 9120h | 122.13h | ARP | Tommy Bysted, Nokia | Rel-6 | TSG | Paolo |  | tommy.bysted@nokia.com |
| 321 | 51.1 | ARP test scenarios | 111d? | 2003-11-21 A | 2004-04-23 | 5% | 105.45d? |  |  |  | 430d | finish no earlier than 2004-04-23 | GP | 888h | 44.4h | ARP-TS | Tommy Bysted, Nokia | Rel-6 | TSG | Paolo |  | tommy.bysted@nokia.com |
| 322 | 51.2 | **ARP for GMSK modulated voice services** | 101d? | 2004-02-06 | 2004-06-25 |  |  |  |  |  | 385d |  | GP | 2424h |  | ARP-GMSK | Tommy Bysted, Nokia | Rel-6 | TSG | Paolo |  | tommy.bysted@nokia.com |
| 323 | 51.2.1 | Performance requirements in 45.005 | 101d? | 2004-02-06 | 2004-06-25 |  |  |  |  |  | 385d | finish no earlier than 2004-06-25 | GP | 808h |  | ARP-GMSK-Perf |  | Rel-6 | TSG |  |  |  |
| 324 | 51.2.2 | Radio subsystem link control in 45.008 | 101d? | 2004-02-06 | 2004-06-25 |  |  |  |  |  | 385d | finish no earlier than 2004-06-25 | GP | 808h |  | ARP-GMSK-LC |  | Rel-6 | TSG |  |  |  |
| 325 | 51.3 | **ARP for GPRS and EGPRS MCS1-MCS4** | 101d? | 2004-02-06 | 2004-06-25 |  |  |  |  |  | 385d |  | GP | 2424h |  | ARP-GPRSE | Tommy Bysted, Nokia | Rel-6 | TSG | Paolo |  | tommy.bysted@nokia.com |
| 326 | 51.3.1 | Performance requirements in 45.005 | 101d? | 2004-02-06 | 2004-06-25 |  |  |  |  |  | 385d | start no earlier than 2004-02-06 | GP | 808h |  | ARP-GPRSE-Perf |  | Rel-6 | TSG |  |  |  |
| 327 | 51.3.2 | Radio subsystem link control in 45.008 | 101d? | 2004-02-06 | 2004-06-25 |  |  |  |  |  | 385d | start no earlier than 2004-02-06 | GP | 808h |  | ARP-GPRSE-LC |  | Rel-6 | TSG |  |  |  |
| 328 | 51.4 | ARP Capability signalling | 111d? | 2003-11-21 A | 2004-04-23 | 5% | 105.45d? |  |  |  | 430d | finish no earlier than 2004-04-23 | GP | 888h | 44.4h | ARP-CAPSIG | Tommy Bysted, Nokia | Rel-6 | TSG | Paolo |  | tommy.bysted@nokia.com |
| 329 | 51.5 | GERAN MS Conformance test for ARP | 56d? | 2004-08-27 | 2004-11-12 |  |  |  |  |  | 285d | finish no earlier than 2004-11-12 | G3 | 448h |  | ARP-ConfTest | Tommy Bysted, Nokia | Rel-6 | TSG | Michael |  | tommy.bysted@nokia.com |

Notes:
- 309: Approved TSG#20
- 314: Not started
- 315: Not started
- 317: Started
- 318: Started
- 319: Started
- 321: Started
- 322: Not started
- 323: Not started
- 324: Not started
- 325: Not started
- 326: Not started
- 327: Not started
- 328: Started
- 329: Not started

| ID | WBS | Task | Duration | Start | Finish | Complete | Remaining | Total slack | Constraint | Resources | Work | Actual work | Text1 | Text4 | Text5 | Text6 | Text7 | Text8 |
| --- | --- | --- | --- | --- | --- | --- | --- | --- | --- | --- | --- | --- | --- | --- | --- | --- | --- | --- |
| 330 | 52 | **Reduction of PS service interruption in Dual Transfer Mode** | 256d? | 2003-11-21 A | 2004-11-12 | 1% | 252.98d? | 285d |  | G2 | 5808h | 68.58h | PSintDTM | Toby Proctor, Siemens | toby.proctor@roke.co.uk | Rel-6 | TSG | Gert |
| 331 | 52.1 | Use case and requirement definition | 111d? | 2003-11-21 A | 2004-04-23 | 5% | 105.45d? | 430d | finish no earlier than 2004-04-23 | G2 | 888h | 44.4h | PSintDTM-Req | Toby Proctor, Siemens | toby.proctor@roke.co.uk | Rel-6 | TSG | Gert |
| 332 | 52.2 | Performance Study of Current Procedures | 111d? | 2003-11-21 | 2004-04-23 |  |  | 430d | start no earlier than 2003-11-21 | G2 | 888h |  | PSintDTM-Perf | Toby Proctor, Siemens | toby.proctor@roke.co.uk | Rel-6 | TSG | Gert |
| 333 | 52.3 | Reduction of service interruption times and packet loss during Dual Transfer Mode and mobility procedures | 46d? | 2004-04-23 | 2004-06-25 |  |  | 385d | finish no earlier than 2004-06-25 | G2 | 368h |  | PSintDTM-Reduct | Toby Proctor, Siemens | toby.proctor@roke.co.uk | Rel-6 | TSG | Gert |
| 334 | 52.4 | MS Conformance testing | 101d? | 2004-06-25 | 2004-11-12 |  |  | 285d | finish no earlier than 2004-11-12 | G3 | 808h |  | PSintDTM-ConfMS |  |  | Rel-6 | TSG | Michael |
| 335 | 52.5 | BTS Conformance testing | 101d? | 2004-06-25 | 2004-11-12 |  |  | 285d | finish no earlier than 2004-11-12 | G3 | 808h |  | PSintDTM-ConfBTS |  |  | Rel-6 | TSG | Michael |

Notes:
- 331: Started
- 332: Not started
- 333: Not started
- 334: Not started
- 335: Not started
